Schedule from MS Project, 2006-12-22 to 2008-03-19.
alanzy company

## Calendars

- Standard: Mon-Fri 08:00-12:00, 13:00-17:00; Sat-Sun off.

## Schedule

| ID | Task | Duration | Start | Finish | Predecessors | Baseline start | Baseline finish | Baseline duration | Total slack | Free slack | Constraint |
| --- | --- | --- | --- | --- | --- | --- | --- | --- | --- | --- | --- |
| 1 | Excavation to foundations level [Contractor #1 Eng. Hisham Altaamari] | 20d | 2006-12-22 | 2007-01-18 |  | 2006-12-22 | 2007-01-02 | 8d | 210d | 0d |  |
| 2 | Excavation for external works | 6d | 2006-12-22 | 2006-12-29 |  |  |  |  | 308d | 0d |  |
| 3 | Approved filling inside | 7d | 2007-02-21 | 2007-03-01 | 11 |  |  |  | 263d | 0d |  |
| 4 | Approved filling outside | 9d | 2007-02-19 | 2007-03-01 | 13 |  |  |  | 274d |  |  |
| 5 | Crushed aggregate base 200 mm thick inside building | 5d | 2007-03-02 | 2007-03-08 | 3 |  |  |  | 263d | 0d |  |
| 6 | Blinding 100 mm thick under foundations and tie beams | 4d | 2007-01-19 | 2007-01-24 | 1 |  |  |  | 210d | 0d |  |
| 7 | Blinding 50 mm thick under slabs on grade | 3d | 2007-02-26 | 2007-02-28 |  |  |  |  | 113d |  | start no earlier than 2007-02-26 |
| 8 | Blinding 100 mm thick under external works | 4d | 2007-01-01 | 2007-01-04 | 2 |  |  |  | 308d | 13d |  |
| 9 | Reinforced concrete for foundations | 10d | 2007-01-25 | 2007-02-07 |  |  |  |  | 290d |  | start no earlier than 2007-01-25 |
| 10 | Reinforced concrete for tie beams | 4d | 2007-04-18 | 2007-04-23 | 35 |  |  |  | 237d |  |  |
| 11 | Reinforced concrete for columns & column necks | 8d | 2007-02-09 | 2007-02-20 |  |  |  |  | 263d | 0d | start no earlier than 2007-02-09 |
| 12 | Reinforced concrete for slab on grade, 100 mm thick to external pavements | 6d | 2007-03-01 | 2007-03-08 | 7 |  |  |  | 269d |  |  |
| 13 | Reinforced concrete for external basement walls | 15d | 2007-01-29 | 2007-02-16 |  |  |  |  | 274d | 0d | start no earlier than 2007-01-29 |
| 14 | Reinforced concrete for water tank walls | 6d | 2007-01-24 | 2007-01-31 | 8 |  |  |  | 295d |  | start no earlier than 2007-01-24 |
| 15 | Reinforced concrete for external foundations | 5d | 2007-01-15 | 2007-01-19 |  |  |  |  | 296d | 0d | start no earlier than 2007-01-15 |
| 16 | Reinforced concrete for external walls | 7d | 2007-01-22 | 2007-01-30 | 15 |  |  |  | 296d |  |  |
| 17 | Reinforced concrete behind stone elevations | 100d | 2007-03-01 | 2007-07-18 |  |  |  |  | 175d |  | start no earlier than 2007-03-01 |
| 18 | Reinforced concrete for ribbed slabs, 310 mm thick | 100d | 2007-03-07 | 2007-07-24 |  |  |  |  | 171d |  | start no earlier than 2007-03-07 |
| 19 | Reinforced concrete for stair cases (steps & flights) inside | 100d | 2007-03-07 | 2007-07-24 |  |  |  |  | 171d |  | start no earlier than 2007-03-07 |
| 20 | Reinforced concrete for stair cases (steps & flights) outside | 20d | 2007-10-31 | 2007-11-27 | 76 |  |  |  | 81d |  | start no earlier than 2007-04-09 |
| 21 | Deformed high yield steel bar reinforcement for various diameters, generally | 90d | 2007-01-25 | 2007-05-30 | 6 |  |  |  | 210d |  |  |
| 22 | Smooth mild steel bar reinforcement for Y8 mm | 90d | 2007-01-09 | 2007-05-14 |  |  |  |  | 222d |  | start no earlier than 2007-01-09 |
| 23 | Hollow concrete blocks for walls, 100 mm thick | 60d | 2007-03-15 | 2007-06-06 |  |  |  |  | 205d |  | start no earlier than 2007-03-15 |
| 24 | Hollow concrete blocks for walls, 150 mm thick | 30d | 2007-03-15 | 2007-04-25 |  |  |  |  | 235d |  | start no earlier than 2007-03-15 |
| 25 | Hollow concrete blocks for walls, 200 mm thick | 20d | 2007-03-15 | 2007-04-11 |  |  |  |  | 245d |  | start no earlier than 2007-03-15 |
| 26 | Hollow concrete rib blocks | 25d | 2007-03-01 | 2007-04-04 |  |  |  |  | 250d |  | start no earlier than 2007-03-01 |
| 27 | concrete blocks, 100 mm thick for external walls of basement | 15d | 2007-03-15 | 2007-04-04 |  |  |  |  | 250d |  | start no earlier than 2007-03-15 |
| 28 | concrete blocks, 100 mm thick, behind the stone walls | 19d | 2007-02-22 | 2007-03-20 |  |  |  |  | 261d |  | start no earlier than 2007-02-22 |
| 29 | Foam concrete, to roofs | 6d | 2007-09-25 | 2007-10-02 |  |  |  |  | 118d | 0d | start no earlier than 2007-09-25 |
| 30 | Cement sand screed, to roofs | 3d | 2007-10-03 | 2007-10-05 | 29 |  |  |  | 118d |  |  |
| 31 | 4 mm thick torch applied modified bituminous water-proofing membrane | 4d | 2007-10-22 | 2007-10-25 |  |  |  |  | 104d |  | start no earlier than 2007-10-22 |
| 32 | 4 mm thick torch applied modified bituminous polymer water-proofing membrane, for slabs on grade | 4d | 2007-04-09 | 2007-04-12 |  |  |  |  | 244d |  | start no earlier than 2007-04-09 |
| 33 | 4 mm thick torch applied modified bituminous polymer water-proofing membrane, to basement walls | 6d | 2007-02-22 | 2007-03-01 |  |  |  |  | 274d |  | start no earlier than 2007-02-22 |
| 34 | Pvc water stop for water tank walls | 1d | 2008-03-19 | 2008-03-19 | 92 |  |  |  | 0d |  |  |
| 35 | Damp proofing membrane to basement walls | 13d | 2007-03-30 | 2007-04-17 |  |  |  |  | 237d | 0d | start no earlier than 2007-03-30 |
| 36 | Local ajlon stone, case 1 mechanical push | 100d | 2007-02-15 | 2007-07-04 |  |  |  |  | 185d |  | start no earlier than 2007-02-15 |
| 37 | Local ajlon stone, case 2 light chisled face finish | 100d | 2007-02-15 | 2007-07-04 |  |  |  |  | 185d |  | start no earlier than 2007-02-15 |
| 38 | Local ajlon stone, case 3 rough chirled face finish | 100d | 2007-02-15 | 2007-07-04 |  |  |  |  | 185d |  | start no earlier than 2007-02-15 |
| 39 | Local ajlon stone, case 4 face finish | 120d | 2007-02-15 | 2007-08-01 |  |  |  |  | 165d |  | start no earlier than 2007-02-15 |
| 40 | Stone coping local ajlon | 20d | 2007-09-18 | 2007-10-15 |  |  |  |  | 112d |  | start no earlier than 2007-09-18 |
| 41 | Approved first quality karak marble grey color | 30d | 2007-04-16 | 2007-05-25 |  |  |  |  | 213d |  | start no earlier than 2007-04-16 |
| 42 | Ajlon cornice stone to walls | 10d | 2007-05-01 | 2007-05-14 |  |  |  |  | 222d |  | start no earlier than 2007-05-01 |
| 43 | Precast terrazzo tiles, to floors, size 400*100*30 mm for guards rooms | 4d | 2007-04-16 | 2007-04-19 |  |  |  |  | 239d |  | start no earlier than 2007-04-16 |
| 44 | Approved first quality JERUSALEM stone, to floors of saloons, living, Tv and master bedrooms areas 600*600*20 mm thick | 30d | 2007-04-16 | 2007-05-25 |  |  |  |  | 162d | 0d | start no earlier than 2007-04-16 |
| 45 | To skirting size 600*100*6 mm thick | 6d | 2007-05-28 | 2007-06-04 | 44 |  |  |  | 162d | 0d |  |
| 46 | (STAND BY ITEM) DITTO BUT ITALIAN MARBLE, to floors of saloons, living, TV and master bedrooms areas 600*600*20 mm thick | 30d | 2007-04-16 | 2007-05-25 |  |  |  |  | 207d | 0d | start no earlier than 2007-04-16 |
| 47 | To skirting size 600*100*6 mm thick | 6d | 2007-05-28 | 2007-06-04 | 46 |  |  |  | 207d |  |  |
| 48 | Ditto but Omani or stone like ceramic tiles, to floors 400*400*20 mm thick | 30d | 2007-04-16 | 2007-05-25 |  |  |  |  | 161d | 0d | start no earlier than 2007-04-16 |
| 49 | To skirting size 300*100*6 mm thick | 6d | 2007-05-28 | 2007-06-04 | 48 |  |  |  | 161d | 0d |  |
| 50 | Imported Spanish Ceramic, To kitchens floors size 400*400*9 mm thick | 17d | 2007-06-05 | 2007-06-27 | 49 |  |  |  | 161d | 0d |  |
| 51 | Ditto but EMIRATES R.A.K ceramic, To floors, size 300*300*9 mm thick for maids rooms | 3d | 2007-06-28 | 2007-07-02 | 50 |  |  |  | 161d | 0d |  |
| 52 | To skirting, size 300*100*6 mm thick for maids rooms | 1d | 2007-07-03 | 2007-07-03 | 51 |  |  |  | 161d | 0d |  |
| 53 | Ditto but local ceramic for boiler and maids bathrooms 200*200*9 mm | 6d | 2007-07-04 | 2007-07-11 | 52 |  |  |  | 161d | 0d |  |
| 54 | One piece JERUSALEM stone to steps, to treads and risers | 30d | 2007-06-05 | 2007-07-16 | 45 |  |  |  | 162d | 0d |  |
| 55 | Skirting to flights 6 mm thick | 10d | 2007-07-17 | 2007-07-30 | 54 |  |  |  | 162d | 0d |  |
| 56 | One piece gravelled tiles to external steps, to treads and risers | 3d | 2007-07-31 | 2007-08-02 | 55 |  |  |  | 162d | 0d |  |
| 57 | Skirting to flights 6 mm thick | 2d | 2007-08-03 | 2007-08-06 | 56 |  |  |  | 162d |  |  |
| 58 | Precast interlock concrete cement floor tiles, to walkway at parking and ramps size 400*400*40 mm | 10d | 2007-12-03 | 2007-12-14 |  |  |  |  | 68d |  | start no earlier than 2007-12-03 |
| 59 | Standby itme ditto but basalt stone | 10d | 2007-12-03 | 2007-12-14 |  |  |  |  | 64d | 0d | start no earlier than 2007-12-03 |
| 60 | Precast concrete cement floor tiles, for external paving | 5d | 2007-12-17 | 2007-12-21 | 59 |  |  |  | 63d |  |  |
| 61 | Three coats cement and sand (1:4) plastereing, smooth finish, To walls, Internally | 80d | 2007-04-02 | 2007-07-20 |  |  |  |  | 173d |  | start no earlier than 2007-04-02 |
| 62 | To walls, Internally behind ceramic walls | 10d | 2007-05-02 | 2007-05-15 |  |  |  |  | 221d |  | start no earlier than 2007-05-02 |
| 63 | To walls, internlly for water tanks walls | 6d | 2007-04-02 | 2007-04-09 |  |  |  |  | 247d |  | start no earlier than 2007-04-02 |
| 64 | To walls, Externally | 5d | 2007-05-02 | 2007-05-08 |  |  |  |  | 205d | 0d | start no earlier than 2007-05-02 |
| 65 | Glazed imported SPANISH ceramic coloured wall tiles, to walls size 300*300*9 mm thick for bath rooms | 15d | 2007-07-12 | 2007-08-01 | 53 |  |  |  | 161d | 0d |  |
| 66 | Ditto but to walls size 100*100*9 mm thick mosaic for kitchens | 10d | 2007-05-23 | 2007-06-05 |  |  |  |  | 206d |  | start no earlier than 2007-05-23 |
| 67 | Ditto but JERUSALEM wall tiles for basement 1 entrance complete | 5d | 2007-05-23 | 2007-05-29 |  |  |  |  | 211d |  | start no earlier than 2007-05-23 |
| 68 | Ditto but local glazed colored ceramic wall tiles, To walls size 200*200*8 mm thick for Boiler | 4d | 2007-08-02 | 2007-08-07 | 65 |  |  |  | 161d |  |  |
| 69 | To walls size 200*200*8 mm thick for maids rooms (white colour) | 3d | 2007-06-04 | 2007-06-06 |  |  |  |  | 205d |  | start no earlier than 2007-06-04 |
| 70 | Ceiling finishes,Three coats cement and sand (1:4) plastering, smooth finish | 30d | 2007-07-09 | 2007-08-17 |  |  |  |  | 153d |  | start no earlier than 2007-07-09 |

| ID | Task | Duration | Start | Finish | Predecessors | Total slack | Free slack | Constraint |
| --- | --- | --- | --- | --- | --- | --- | --- | --- |
| 71 | JERUSALEM stone cladding, fixed to faces of concrete with 30 mm thick with cement mortar for parking columns | 3d | 2008-01-02 | 2008-01-04 |  | 46d | 0d | start no earlier than 2008-01-02 |
| 72 | JERUSALEM stone cladding, for main entrances | 3d | 2008-01-07 | 2008-01-09 | 71 | 46d | 0d |  |
| 73 | AJLOON stone cladding, for parking walls and entrance | 4d | 2008-01-10 | 2008-01-15 | 72 | 46d |  |  |
| 74 | Suspended ceilings, 12 mm thick gypsum board suspended ceiling panels finished with skim coat, including conceled galvanized suspension system, stepped decorations, strips, for different sevices | 4d | 2008-02-01 | 2008-02-06 |  | 34d |  | start no earlier than 2008-02-01 |
| 75 | 800mm*300 mm height gypsum cornice suspended finished with skim coat, for saloons, TV and dinning ceilings | 7d | 2008-02-01 | 2008-02-11 |  | 27d |  | start no earlier than 2008-02-01 |
| 76 | Internally Emulsion PVA-based paint matt finish for interior, To walls | 65d | 2007-08-01 | 2007-10-30 |  | 81d | 0d | start no earlier than 2007-08-01 |
| 77 | Externally, Resin base water proofing acrylic textured decorative coating, to exterior walls | 22d | 2007-05-21 | 2007-06-19 |  | 196d |  | start no earlier than 2007-05-21 |
| 78 | To walls at roof | 19d | 2007-08-01 | 2007-08-27 |  | 147d |  | start no earlier than 2007-08-01 |
| 79 | Non- toxic epoxy paint including primer all as specified, complete to floor, walls and ceiling of water tanks | 21d | 2007-05-09 | 2007-06-06 | 64 | 205d |  |  |
| 80 | CORNER GUARDS, supply and fix rubber corner guards for columns at parking areas, 100*100 mm, 1200 mm height | 7d | 2007-08-01 | 2007-08-09 |  | 159d |  | start no earlier than 2007-08-01 |
| 81 | Mirrors, 6 mm thick mirrors with 20 mm stainless steel frame including 8 mm thick plywood backing, size 1050*2600 mm high | 4d | 2007-11-30 | 2007-12-05 |  | 46d | 0d | start no earlier than 2007-11-30 |
| 82 | size 1600*1300 mm high | 5d | 2007-12-06 | 2007-12-12 | 81 | 46d | 0d |  |
| 83 | Size 800*1300 mm high | 11d | 2007-12-13 | 2007-12-27 | 82 | 46d | 0d |  |
| 84 | Local KARAK Marble countertop 30 mm thick with molding wash basin including 200 mm dropped cornice, size 1700*600 mm wide | 2d | 2007-12-28 | 2007-12-31 | 83 | 46d | 0d |  |
| 85 | Size 2800*600 mm wide | 1d | 2008-01-01 | 2008-01-01 | 84 | 46d | 0d |  |
| 86 | Size 2000*600 mm wide | 1d | 2008-01-02 | 2008-01-02 | 85 | 46d | 0d |  |
| 87 | Size 1800*600 mm wide | 1d | 2008-01-03 | 2008-01-03 | 86 | 46d | 0d |  |
| 88 | Size 1200*600 mm wide | 2d | 2008-01-04 | 2008-01-07 | 87 | 46d | 0d |  |
| 89 | Size 2200*600 mm wide | 2d | 2008-01-08 | 2008-01-09 | 88 | 46d | 0d |  |
| 90 | Size 1900*600 mm wide | 3d | 2008-01-10 | 2008-01-14 | 89 | 46d | 0d |  |
| 91 | Size 2600*600 mm wide | 1d | 2008-01-15 | 2008-01-15 | 90 | 46d |  |  |
| 92 | Planting, Agricultural soil of clean selected top soil suitable for planting purposes | 22d | 2008-02-18 | 2008-03-18 |  | 0d |  | start no earlier than 2008-02-18 |
| 93 | Slab on grade, 100 mm thick, to building | 6d | 2007-03-09 | 2007-03-16 | 5 | 263d |  |  |
