Schedule from MS Project, 2006-12-22 to 2008-03-17.
alanzy company

## Calendars

- Standard: Mon-Fri 08:00-12:00, 13:00-17:00; Sat-Sun off.

## Schedule

| ID | Task | Duration | Start | Finish | Predecessors | Baseline start | Baseline finish | Baseline duration | Total slack | Free slack | Constraint |
| --- | --- | --- | --- | --- | --- | --- | --- | --- | --- | --- | --- |
| 1 | Excavation to foundations level [Contractor #10 Mr. Sherif Tawfik] | 10d | 2006-12-22 | 2007-01-04 |  | 2006-12-22 | 2007-01-04 | 10d | 279d | 0d |  |
| 2 | Excavation for external works | 7d | 2006-12-22 | 2007-01-01 |  | 2006-12-22 | 2007-01-01 | 7d | 308d | 0d |  |
| 3 | Approved filling inside | 10d | 2007-02-21 | 2007-03-06 | 11 | 2007-02-21 | 2007-03-06 | 10d | 259d | 0d |  |
| 4 | Approved filling outside | 10d | 2007-02-19 | 2007-03-02 | 13 | 2007-02-19 | 2007-03-02 | 10d | 271d |  |  |
| 5 | Crushed aggregate base 200 mm thick inside building | 5d | 2007-03-07 | 2007-03-13 | 3 | 2007-03-07 | 2007-03-13 | 5d | 259d | 0d |  |
| 6 | Blinding 100 mm thick under foundations and tie beams | 3d | 2007-01-05 | 2007-01-09 | 1 | 2007-01-05 | 2007-01-09 | 3d | 279d | 0d |  |
| 7 | Blinding 50 mm thick under slabs on grade | 2d | 2007-02-26 | 2007-02-27 |  | 2007-02-26 | 2007-02-27 | 2d | 270d | 0d | start no earlier than 2007-02-26 |
| 8 | Blinding 100 mm thick under external works | 2d | 2007-01-02 | 2007-01-03 | 2 | 2007-01-02 | 2007-01-03 | 2d | 308d | 14d |  |
| 9 | Reinforced concrete for foundations | 7d | 2007-01-15 | 2007-01-23 |  | 2007-01-15 | 2007-01-23 | 7d | 299d |  | start no earlier than 2007-01-15 |
| 10 | Reinforced concrete for tie beams | 7d | 2007-05-04 | 2007-05-14 | 35 | 2007-05-04 | 2007-05-14 | 7d | 220d |  |  |
| 11 | Reinforced concrete for columns & column necks | 8d | 2007-02-09 | 2007-02-20 |  | 2007-02-09 | 2007-02-20 | 8d | 259d | 0d | start no earlier than 2007-02-09 |
| 12 | Reinforced concrete for slab on grade, 100 mm thick to external pavements | 4d | 2007-02-28 | 2007-03-05 | 7 | 2007-02-28 | 2007-03-05 | 4d | 270d |  |  |
| 13 | Reinforced concrete for external basement walls | 15d | 2007-01-29 | 2007-02-16 |  | 2007-01-29 | 2007-02-16 | 15d | 271d | 0d | start no earlier than 2007-01-29 |
| 14 | Reinforced concrete for water tank walls | 5d | 2007-01-24 | 2007-01-30 | 8 | 2007-01-24 | 2007-01-30 | 5d | 294d |  | start no earlier than 2007-01-24 |
| 15 | Reinforced concrete for external foundations | 7d | 2007-01-15 | 2007-01-23 |  | 2007-01-15 | 2007-01-23 | 7d | 284d | 0d | start no earlier than 2007-01-15 |
| 16 | Reinforced concrete for external walls | 15d | 2007-01-24 | 2007-02-13 | 15 | 2007-01-24 | 2007-02-13 | 15d | 284d |  |  |
| 17 | Reinforced concrete behind stone elevations | 20d | 2007-03-01 | 2007-03-28 |  | 2007-03-01 | 2007-03-28 | 20d | 253d |  | start no earlier than 2007-03-01 |
| 18 | Reinforced concrete for ribbed slabs, 310 mm thick | 35d | 2007-03-07 | 2007-04-24 |  | 2007-03-07 | 2007-04-24 | 35d | 234d |  | start no earlier than 2007-03-07 |
| 19 | Reinforced concrete for stair cases (steps & flights) inside | 20d | 2007-03-07 | 2007-04-03 |  | 2007-03-07 | 2007-04-03 | 20d | 249d |  | start no earlier than 2007-03-07 |
| 20 | Reinforced concrete for stair cases (steps & flights) outside | 15d | 2007-09-12 | 2007-10-02 | 76 | 2007-09-12 | 2007-10-02 | 15d | 119d |  | start no earlier than 2007-04-09 |
| 21 | Deformed high yield steel bar reinforcement for various diameters, generally | 30d | 2007-01-10 | 2007-02-20 | 6 | 2007-01-10 | 2007-02-20 | 30d | 279d |  |  |
| 22 | Smooth mild steel bar reinforcement for Y8 mm | 30d | 2007-01-09 | 2007-02-19 |  | 2007-01-09 | 2007-02-19 | 30d | 280d |  | start no earlier than 2007-01-09 |
| 23 | Hollow concrete blocks for walls, 100 mm thick | 12d | 2007-03-15 | 2007-03-30 |  | 2007-03-15 | 2007-03-30 | 12d | 251d |  | start no earlier than 2007-03-15 |
| 24 | Hollow concrete blocks for walls, 150 mm thick | 150d | 2007-03-15 | 2007-10-10 |  | 2007-03-15 | 2007-10-10 | 150d | 113d |  | start no earlier than 2007-03-15 |
| 25 | Hollow concrete blocks for walls, 200 mm thick | 30d | 2007-03-15 | 2007-04-25 |  | 2007-03-15 | 2007-04-25 | 30d | 233d |  | start no earlier than 2007-03-15 |
| 26 | Hollow concrete rib blocks | 10d | 2007-03-01 | 2007-03-14 |  | 2007-03-01 | 2007-03-14 | 10d | 263d |  | start no earlier than 2007-03-01 |
| 27 | concrete blocks, 100 mm thick for external walls of basement | 30d | 2007-03-15 | 2007-04-25 |  | 2007-03-15 | 2007-04-25 | 30d | 233d |  | start no earlier than 2007-03-15 |
| 28 | concrete blocks, 100 mm thick, behind the stone walls | 35d | 2007-02-22 | 2007-04-11 |  | 2007-02-22 | 2007-04-11 | 35d | 243d |  | start no earlier than 2007-02-22 |
| 29 | Foam concrete, to roofs | 10d | 2007-09-25 | 2007-10-08 |  | 2007-09-25 | 2007-10-08 | 10d | 105d | 0d | start no earlier than 2007-09-25 |
| 30 | Cement sand screed, to roofs | 10d | 2007-10-09 | 2007-10-22 | 29 | 2007-10-09 | 2007-10-22 | 10d | 105d |  |  |
| 31 | 4 mm thick torch applied modified bituminous water-proofing membrane | 12d | 2007-10-22 | 2007-11-06 |  | 2007-10-22 | 2007-11-06 | 12d | 94d |  | start no earlier than 2007-10-22 |
| 32 | 4 mm thick torch applied modified bituminous polymer water-proofing membrane, for slabs on grade | 17d | 2007-04-09 | 2007-05-01 |  | 2007-04-09 | 2007-05-01 | 17d | 229d |  | start no earlier than 2007-04-09 |
| 33 | 4 mm thick torch applied modified bituminous polymer water-proofing membrane, to basement walls | 25d | 2007-02-22 | 2007-03-28 |  | 2007-02-22 | 2007-03-28 | 25d | 253d |  | start no earlier than 2007-02-22 |
| 34 | Pvc water stop for water tank walls | 6d | 2008-03-10 | 2008-03-17 | 92 | 2008-03-10 | 2008-03-17 | 6d | 0d |  |  |
| 35 | Damp proofing membrane to basement walls | 25d | 2007-03-30 | 2007-05-03 |  | 2007-03-30 | 2007-05-03 | 25d | 220d | 0d | start no earlier than 2007-03-30 |
| 36 | Local ajlon stone, case 1 mechanical push | 60d | 2007-02-15 | 2007-05-09 |  | 2007-02-15 | 2007-05-09 | 60d | 223d |  | start no earlier than 2007-02-15 |
| 37 | Local ajlon stone, case 2 light chisled face finish | 60d | 2007-02-15 | 2007-05-09 |  | 2007-02-15 | 2007-05-09 | 60d | 223d |  | start no earlier than 2007-02-15 |
| 38 | Local ajlon stone, case 3 rough chirled face finish | 60d | 2007-02-15 | 2007-05-09 |  | 2007-02-15 | 2007-05-09 | 60d | 223d |  | start no earlier than 2007-02-15 |
| 39 | Local ajlon stone, case 4 face finish | 65d | 2007-02-15 | 2007-05-16 |  | 2007-02-15 | 2007-05-16 | 65d | 218d |  | start no earlier than 2007-02-15 |
| 40 | Stone coping local ajlon | 7d | 2007-09-18 | 2007-09-26 |  | 2007-09-18 | 2007-09-26 | 7d | 123d |  | start no earlier than 2007-09-18 |
| 41 | Approved first quality karak marble grey color | 6d | 2007-04-16 | 2007-04-23 |  | 2007-04-16 | 2007-04-23 | 6d | 235d |  | start no earlier than 2007-04-16 |
| 42 | Ajlon cornice stone to walls | 7d | 2007-05-01 | 2007-05-09 |  | 2007-05-01 | 2007-05-09 | 7d | 223d |  | start no earlier than 2007-05-01 |
| 43 | Precast terrazzo tiles, to floors, size 400*100*30 mm for guards rooms | 10d | 2007-04-16 | 2007-04-27 |  | 2007-04-16 | 2007-04-27 | 10d | 231d |  | start no earlier than 2007-04-16 |
| 44 | Approved first quality JERUSALEM stone, to floors of saloons, living, Tv and master bedrooms areas 600*600*20 mm thick | 15d | 2007-04-16 | 2007-05-04 |  | 2007-04-16 | 2007-05-04 | 15d | 198d | 0d | start no earlier than 2007-04-16 |
| 45 | To skirting size 600*100*6 mm thick | 12d | 2007-05-07 | 2007-05-22 | 44 | 2007-05-07 | 2007-05-22 | 12d | 198d | 0d |  |
| 46 | (STAND BY ITEM) DITTO BUT ITALIAN MARBLE, to floors of saloons, living, TV and master bedrooms areas 600*600*20 mm thick | 15d | 2007-04-16 | 2007-05-04 |  | 2007-04-16 | 2007-05-04 | 15d | 214d | 0d | start no earlier than 2007-04-16 |
| 47 | To skirting size 600*100*6 mm thick | 12d | 2007-05-07 | 2007-05-22 | 46 | 2007-05-07 | 2007-05-22 | 12d | 214d |  |  |
| 48 | Ditto but Omani or stone like ceramic tiles, to floors 400*400*20 mm thick | 12d | 2007-04-16 | 2007-05-01 |  | 2007-04-16 | 2007-05-01 | 12d | 167d | 0d | start no earlier than 2007-04-16 |
| 49 | To skirting size 300*100*6 mm thick | 10d | 2007-05-02 | 2007-05-15 | 48 | 2007-05-02 | 2007-05-15 | 10d | 167d | 0d |  |
| 50 | Imported Spanish Ceramic, To kitchens floors size 400*400*9 mm thick | 15d | 2007-05-16 | 2007-06-05 | 49 | 2007-05-16 | 2007-06-05 | 15d | 167d | 0d |  |
| 51 | Ditto but EMIRATES R.A.K ceramic, To floors, size 300*300*9 mm thick for maids rooms | 7d | 2007-06-06 | 2007-06-14 | 50 | 2007-06-06 | 2007-06-14 | 7d | 167d | 0d |  |
| 52 | To skirting, size 300*100*6 mm thick for maids rooms | 7d | 2007-06-15 | 2007-06-25 | 51 | 2007-06-15 | 2007-06-25 | 7d | 167d | 0d |  |
| 53 | Ditto but local ceramic for boiler and maids bathrooms 200*200*9 mm | 10d | 2007-06-26 | 2007-07-09 | 52 | 2007-06-26 | 2007-07-09 | 10d | 167d | 0d |  |
| 54 | One piece JERUSALEM stone to steps, to treads and risers | 5d | 2007-05-23 | 2007-05-29 | 45 | 2007-05-23 | 2007-05-29 | 5d | 198d | 0d |  |
| 55 | Skirting to flights 6 mm thick | 4d | 2007-05-30 | 2007-06-04 | 54 | 2007-05-30 | 2007-06-04 | 4d | 198d | 0d |  |
| 56 | One piece gravelled tiles to external steps, to treads and risers | 4d | 2007-06-05 | 2007-06-08 | 55 | 2007-06-05 | 2007-06-08 | 4d | 198d | 0d |  |
| 57 | Skirting to flights 6 mm thick | 3d | 2007-06-11 | 2007-06-13 | 56 | 2007-06-11 | 2007-06-13 | 3d | 198d |  |  |
| 58 | Precast interlock concrete cement floor tiles, to walkway at parking and ramps size 400*400*40 mm | 12d | 2007-12-03 | 2007-12-18 |  | 2007-12-03 | 2007-12-18 | 12d | 64d |  | start no earlier than 2007-12-03 |
| 59 | Standby itme ditto but basalt stone | 11d | 2007-12-03 | 2007-12-17 |  | 2007-12-03 | 2007-12-17 | 11d | 57d | 0d | start no earlier than 2007-12-03 |
| 60 | Precast concrete cement floor tiles, for external paving | 8d | 2007-12-18 | 2007-12-27 | 59 | 2007-12-18 | 2007-12-27 | 8d | 57d |  |  |
| 61 | Three coats cement and sand (1:4) plastereing, smooth finish, To walls, Internally | 96d | 2007-04-02 | 2007-08-13 |  | 2007-04-02 | 2007-08-13 | 96d | 155d |  | start no earlier than 2007-04-02 |
| 62 | To walls, Internally behind ceramic walls | 30d | 2007-05-02 | 2007-06-12 |  | 2007-05-02 | 2007-06-12 | 30d | 199d |  | start no earlier than 2007-05-02 |
| 63 | To walls, internlly for water tanks walls | 9d | 2007-04-02 | 2007-04-12 |  | 2007-04-02 | 2007-04-12 | 9d | 242d |  | start no earlier than 2007-04-02 |
| 64 | To walls, Externally | 10d | 2007-05-02 | 2007-05-15 |  | 2007-05-02 | 2007-05-15 | 10d | 204d | 0d | start no earlier than 2007-05-02 |
| 65 | Glazed imported SPANISH ceramic coloured wall tiles, to walls size 300*300*9 mm thick for bath rooms | 8d | 2007-07-10 | 2007-07-19 | 53 | 2007-07-10 | 2007-07-19 | 8d | 167d | 0d |  |
| 66 | Ditto but to walls size 100*100*9 mm thick mosaic for kitchens | 8d | 2007-05-23 | 2007-06-01 |  | 2007-05-23 | 2007-06-01 | 8d | 206d |  | start no earlier than 2007-05-23 |
| 67 | Ditto but JERUSALEM wall tiles for basement 1 entrance complete | 3d | 2007-05-23 | 2007-05-25 |  | 2007-05-23 | 2007-05-25 | 3d | 211d |  | start no earlier than 2007-05-23 |
| 68 | Ditto but local glazed colored ceramic wall tiles, To walls size 200*200*8 mm thick for Boiler | 5d | 2007-07-20 | 2007-07-26 | 65 | 2007-07-20 | 2007-07-26 | 5d | 167d |  |  |
| 69 | To walls size 200*200*8 mm thick for maids rooms (white colour) | 5d | 2007-06-04 | 2007-06-08 |  | 2007-06-04 | 2007-06-08 | 5d | 201d |  | start no earlier than 2007-06-04 |
| 70 | Ceiling finishes,Three coats cement and sand (1:4) plastering, smooth finish | 35d | 2007-07-09 | 2007-08-24 |  | 2007-07-09 | 2007-08-24 | 35d | 146d |  | start no earlier than 2007-07-09 |

| ID | Task | Duration | Start | Finish | Predecessors | Baseline start | Baseline finish | Baseline duration | Total slack | Free slack | Constraint |
| --- | --- | --- | --- | --- | --- | --- | --- | --- | --- | --- | --- |
| 71 | JERUSALEM stone cladding, fixed to faces of concrete with 30 mm thick with cement mortar for parking columns | 6d | 2008-01-02 | 2008-01-09 |  | 2008-01-02 | 2008-01-09 | 6d | 37d | 0d | start no earlier than 2008-01-02 |
| 72 | JERUSALEM stone cladding, for main entrances | 4d | 2008-01-10 | 2008-01-15 | 71 | 2008-01-10 | 2008-01-15 | 4d | 37d | 0d |  |
| 73 | AJLOON stone cladding, for parking walls and entrance | 7d | 2008-01-16 | 2008-01-24 | 72 | 2008-01-16 | 2008-01-24 | 7d | 37d |  |  |
| 74 | Suspended ceilings, 12 mm thick gypsum board suspended ceiling panels finished with skim coat, including conceled galvanized suspension system, stepped decorations, strips, for different sevices | 5d | 2008-02-01 | 2008-02-07 |  | 2008-02-01 | 2008-02-07 | 5d | 27d |  | start no earlier than 2008-02-01 |
| 75 | 800mm*300 mm height gypsum cornice suspended finished with skim coat, for saloons, TV and dinning ceilings | 26d | 2008-02-01 | 2008-03-07 |  | 2008-02-01 | 2008-03-07 | 26d | 6d |  | start no earlier than 2008-02-01 |
| 76 | Internally Emulsion PVA-based paint matt finish for interior, To walls | 30d | 2007-08-01 | 2007-09-11 |  | 2007-08-01 | 2007-09-11 | 30d | 119d | 0d | start no earlier than 2007-08-01 |
| 77 | Externally, Resin base water proofing acrylic textured decorative coating, to exterior walls | 15d | 2007-05-21 | 2007-06-08 |  | 2007-05-21 | 2007-06-08 | 15d | 201d |  | start no earlier than 2007-05-21 |
| 78 | To walls at roof | 10d | 2007-08-01 | 2007-08-14 |  | 2007-08-01 | 2007-08-14 | 10d | 154d |  | start no earlier than 2007-08-01 |
| 79 | Non- toxic epoxy paint including primer all as specified, complete to floor, walls and ceiling of water tanks | 15d | 2007-05-16 | 2007-06-05 | 64 | 2007-05-16 | 2007-06-05 | 15d | 204d |  |  |
| 80 | CORNER GUARDS, supply and fix rubber corner guards for columns at parking areas, 100*100 mm, 1200 mm height | 7d | 2007-08-01 | 2007-08-09 |  | 2007-08-01 | 2007-08-09 | 7d | 157d |  | start no earlier than 2007-08-01 |
| 81 | Mirrors, 6 mm thick mirrors with 20 mm stainless steel frame including 8 mm thick plywood backing, size 1050*2600 mm high | 3d | 2007-11-30 | 2007-12-04 |  | 2007-11-30 | 2007-12-04 | 3d | 49d | 0d | start no earlier than 2007-11-30 |
| 82 | size 1600*1300 mm high | 4d | 2007-12-05 | 2007-12-10 | 81 | 2007-12-05 | 2007-12-10 | 4d | 49d | 0d |  |
| 83 | Size 800*1300 mm high | 8d | 2007-12-11 | 2007-12-20 | 82 | 2007-12-11 | 2007-12-20 | 8d | 49d | 0d |  |
| 84 | Local KARAK Marble countertop 30 mm thick with molding wash basin including 200 mm dropped cornice, size 1700*600 mm wide | 2d | 2007-12-21 | 2007-12-24 | 83 | 2007-12-21 | 2007-12-24 | 2d | 49d | 0d |  |
| 85 | Size 2800*600 mm wide | 1d | 2007-12-25 | 2007-12-25 | 84 | 2007-12-25 | 2007-12-25 | 1d | 49d | 0d |  |
| 86 | Size 2000*600 mm wide | 1d | 2007-12-26 | 2007-12-26 | 85 | 2007-12-26 | 2007-12-26 | 1d | 49d | 0d |  |
| 87 | Size 1800*600 mm wide | 1d | 2007-12-27 | 2007-12-27 | 86 | 2007-12-27 | 2007-12-27 | 1d | 49d | 0d |  |
| 88 | Size 1200*600 mm wide | 2d | 2007-12-28 | 2007-12-31 | 87 | 2007-12-28 | 2007-12-31 | 2d | 49d | 0d |  |
| 89 | Size 2200*600 mm wide | 2d | 2008-01-01 | 2008-01-02 | 88 | 2008-01-01 | 2008-01-02 | 2d | 49d | 0d |  |
| 90 | Size 1900*600 mm wide | 3d | 2008-01-03 | 2008-01-07 | 89 | 2008-01-03 | 2008-01-07 | 3d | 49d | 0d |  |
| 91 | Size 2600*600 mm wide | 1d | 2008-01-08 | 2008-01-08 | 90 | 2008-01-08 | 2008-01-08 | 1d | 49d |  |  |
| 92 | Planting, Agricultural soil of clean selected top soil suitable for planting purposes | 15d | 2008-02-18 | 2008-03-07 |  | 2008-02-18 | 2008-03-07 | 15d | 0d |  | start no earlier than 2008-02-18 |
| 93 | Slab on grade, 100 mm thick, to building | 5d | 2007-03-14 | 2007-03-20 | 5 | 2007-03-14 | 2007-03-20 | 5d | 259d |  |  |
