Schedule from MS Project, 2006-12-22 to 2008-03-25.
alanzy company

## Calendars

- Standard: Mon-Fri 08:00-12:00, 13:00-17:00; Sat-Sun off.

## Schedule

| ID | Task | Duration | Start | Finish | Predecessors | Baseline start | Baseline finish | Baseline duration | Total slack | Free slack | Constraint |
| --- | --- | --- | --- | --- | --- | --- | --- | --- | --- | --- | --- |
| 1 | Excavation to foundations level [Contractor #4 Eng. Mazen haddad] | 8d | 2006-12-22 | 2007-01-02 |  | 2006-12-22 | 2007-01-02 | 8d | 47d | 0d |  |
| 2 | Excavation for external works | 5d | 2006-12-22 | 2006-12-28 |  | 2006-12-22 | 2006-12-28 | 5d | 7d | 0d |  |
| 3 | Approved filling inside | 7d | 2007-02-15 | 2007-02-23 | 11 | 2007-02-15 | 2007-02-23 | 7d | 112d | 0d |  |
| 4 | Approved filling outside | 7d | 2007-02-19 | 2007-02-27 | 13 | 2007-02-19 | 2007-02-27 | 7d | 114d |  |  |
| 5 | Crushed aggregate base 200 mm thick inside building | 4d | 2007-02-26 | 2007-03-01 | 3 | 2007-02-26 | 2007-03-01 | 4d | 112d |  |  |
| 6 | Blinding 100 mm thick under foundations and tie beams | 4d | 2007-01-03 | 2007-01-08 | 1 | 2007-01-03 | 2007-01-08 | 4d | 47d | 0d |  |
| 7 | Blinding 50 mm thick under slabs on grade | 3d | 2007-02-26 | 2007-02-28 |  | 2007-02-26 | 2007-02-28 | 3d | 113d |  | start no earlier than 2007-02-26 |
| 8 | Blinding 100 mm thick under external works | 8d | 2006-12-29 | 2007-01-09 | 2 | 2006-12-29 | 2007-01-09 | 8d | 149d |  |  |
| 9 | Reinforced concrete for foundations | 8d | 2007-01-15 | 2007-01-24 |  | 2007-01-15 | 2007-01-24 | 8d | 138d |  | start no earlier than 2007-01-15 |
| 10 | Reinforced concrete for tie beams | 6d | 2007-05-07 | 2007-05-14 | 35 | 2007-05-07 | 2007-05-14 | 6d | 162d |  |  |
| 11 | Reinforced concrete for columns & column necks | 4d | 2007-02-09 | 2007-02-14 |  | 2007-02-09 | 2007-02-14 | 4d | 112d | 0d | start no earlier than 2007-02-09 |
| 12 | Reinforced concrete for slab on grade, 100 mm thick to external pavements | 5d | 2007-03-01 | 2007-03-07 | 7 | 2007-03-01 | 2007-03-07 | 5d | 108d |  |  |
| 13 | Reinforced concrete for external basement walls | 15d | 2007-01-29 | 2007-02-16 |  | 2007-01-29 | 2007-02-16 | 15d | 114d | 0d | start no earlier than 2007-01-29 |
| 14 | Reinforced concrete for water tank walls | 8d | 2007-01-24 | 2007-02-02 | 8 | 2007-01-24 | 2007-02-02 | 8d | 178d |  | start no earlier than 2007-01-24 |
| 15 | Reinforced concrete for external foundations | 7d | 2007-01-15 | 2007-01-23 |  | 2007-01-15 | 2007-01-23 | 7d | 139d |  | start no earlier than 2007-01-15 |
| 16 | Reinforced concrete for external walls | 15d | 2007-01-24 | 2007-02-13 | 15 | 2007-01-24 | 2007-02-13 | 15d | 171d |  |  |
| 17 | Reinforced concrete behind stone elevations | 150d | 2007-03-01 | 2007-09-26 |  | 2007-03-01 | 2007-09-26 | 150d | 10d |  | start no earlier than 2007-03-01 |
| 18 | Reinforced concrete for ribbed slabs, 310 mm thick | 130d | 2007-03-07 | 2007-09-04 |  | 2007-03-07 | 2007-09-04 | 130d | 26d |  | start no earlier than 2007-03-07 |
| 19 | Reinforced concrete for stair cases (steps & flights) inside | 130d | 2007-03-07 | 2007-09-04 |  | 2007-03-07 | 2007-09-04 | 130d | 26d |  | start no earlier than 2007-03-07 |
| 20 | Reinforced concrete for stair cases (steps & flights) outside | 20d | 2007-11-07 | 2007-12-04 | 76 | 2007-11-07 | 2007-12-04 | 20d | 80d |  | start no earlier than 2007-04-09 |
| 21 | Deformed high yield steel bar reinforcement for various diameters, generally | 150d | 2007-01-09 | 2007-08-06 | 6 | 2007-01-09 | 2007-08-06 | 150d | 47d |  |  |
| 22 | Smooth mild steel bar reinforcement for Y8 mm | 150d | 2007-01-09 | 2007-08-06 |  | 2007-01-09 | 2007-08-06 | 150d | 47d |  | start no earlier than 2007-01-09 |
| 23 | Hollow concrete blocks for walls, 100 mm thick | 150d | 2007-03-15 | 2007-10-10 |  | 2007-03-15 | 2007-10-10 | 150d | 55d |  | start no earlier than 2007-03-15 |
| 24 | Hollow concrete blocks for walls, 150 mm thick | 150d | 2007-03-15 | 2007-10-10 |  | 2007-03-15 | 2007-10-10 | 150d | 55d |  | start no earlier than 2007-03-15 |
| 25 | Hollow concrete blocks for walls, 200 mm thick | 150d | 2007-03-15 | 2007-10-10 |  | 2007-03-15 | 2007-10-10 | 150d | 55d |  | start no earlier than 2007-03-15 |
| 26 | Hollow concrete rib blocks | 150d | 2007-03-01 | 2007-09-26 |  | 2007-03-01 | 2007-09-26 | 150d | 10d |  | start no earlier than 2007-03-01 |
| 27 | concrete blocks, 100 mm thick for external walls of basement | 30d | 2007-03-15 | 2007-04-25 |  | 2007-03-15 | 2007-04-25 | 30d | 120d |  | start no earlier than 2007-03-15 |
| 28 | concrete blocks, 100 mm thick, behind the stone walls | 150d | 2007-02-22 | 2007-09-19 |  | 2007-02-22 | 2007-09-19 | 150d | 15d |  | start no earlier than 2007-02-22 |
| 29 | Foam concrete, to roofs | 7d | 2007-09-25 | 2007-10-03 |  | 2007-09-25 | 2007-10-03 | 7d | 52d | 0d | start no earlier than 2007-09-25 |
| 30 | Cement sand screed, to roofs | 8d | 2007-10-04 | 2007-10-15 | 29 | 2007-10-04 | 2007-10-15 | 8d | 52d |  |  |
| 31 | 4 mm thick torch applied modified bituminous water-proofing membrane | 10d | 2007-10-22 | 2007-11-02 |  | 2007-10-22 | 2007-11-02 | 10d | 38d |  | start no earlier than 2007-10-22 |
| 32 | 4 mm thick torch applied modified bituminous polymer water-proofing membrane, for slabs on grade | 14d | 2007-04-09 | 2007-04-26 |  | 2007-04-09 | 2007-04-26 | 14d | 174d |  | start no earlier than 2007-04-09 |
| 33 | 4 mm thick torch applied modified bituminous polymer water-proofing membrane, to basement walls | 25d | 2007-02-22 | 2007-03-28 |  | 2007-02-22 | 2007-03-28 | 25d | 195d |  | start no earlier than 2007-02-22 |
| 34 | Pvc water stop for water tank walls | 5d | 2008-03-19 | 2008-03-25 | 92 | 2008-03-19 | 2008-03-25 | 5d | 0d |  |  |
| 35 | Damp proofing membrane to basement walls | 26d | 2007-03-30 | 2007-05-04 |  | 2007-03-30 | 2007-05-04 | 26d | 162d | 0d | start no earlier than 2007-03-30 |
| 36 | Local ajlon stone, case 1 mechanical push | 150d | 2007-02-15 | 2007-09-12 |  | 2007-02-15 | 2007-09-12 | 150d | 75d |  | start no earlier than 2007-02-15 |
| 37 | Local ajlon stone, case 2 light chisled face finish | 150d | 2007-02-15 | 2007-09-12 |  | 2007-02-15 | 2007-09-12 | 150d | 75d |  | start no earlier than 2007-02-15 |
| 38 | Local ajlon stone, case 3 rough chirled face finish | 150d | 2007-02-15 | 2007-09-12 |  | 2007-02-15 | 2007-09-12 | 150d | 75d |  | start no earlier than 2007-02-15 |
| 39 | Local ajlon stone, case 4 face finish | 150d | 2007-02-15 | 2007-09-12 |  | 2007-02-15 | 2007-09-12 | 150d | 75d |  | start no earlier than 2007-02-15 |
| 40 | Stone coping local ajlon | 15d | 2007-09-18 | 2007-10-08 |  | 2007-09-18 | 2007-10-08 | 15d | 57d |  | start no earlier than 2007-09-18 |
| 41 | Approved first quality karak marble grey color | 150d | 2007-04-16 | 2007-11-09 |  | 2007-04-16 | 2007-11-09 | 150d | 33d |  | start no earlier than 2007-04-16 |
| 42 | Ajlon cornice stone to walls | 40d | 2007-05-01 | 2007-06-25 |  | 2007-05-01 | 2007-06-25 | 40d | 132d |  | start no earlier than 2007-05-01 |
| 43 | Precast terrazzo tiles, to floors, size 400*100*30 mm for guards rooms | 5d | 2007-04-16 | 2007-04-20 |  | 2007-04-16 | 2007-04-20 | 5d | 178d |  | start no earlier than 2007-04-16 |
| 44 | Approved first quality JERUSALEM stone, to floors of saloons, living, Tv and master bedrooms areas 600*600*20 mm thick | 9d | 2007-04-16 | 2007-04-26 |  | 2007-04-16 | 2007-04-26 | 9d | 153d | 0d | start no earlier than 2007-04-16 |
| 45 | To skirting size 600*100*6 mm thick | 6d | 2007-04-27 | 2007-05-04 | 44 | 2007-04-27 | 2007-05-04 | 6d | 153d | 0d |  |
| 46 | (STAND BY ITEM) DITTO BUT ITALIAN MARBLE, to floors of saloons, living, TV and master bedrooms areas 600*600*20 mm thick | 4d | 2007-04-16 | 2007-04-19 |  | 2007-04-16 | 2007-04-19 | 4d | 176d | 0d | start no earlier than 2007-04-16 |
| 47 | To skirting size 600*100*6 mm thick | 3d | 2007-04-20 | 2007-04-24 | 46 | 2007-04-20 | 2007-04-24 | 3d | 176d |  |  |
| 48 | Ditto but Omani or stone like ceramic tiles, to floors 400*400*20 mm thick | 6d | 2007-04-16 | 2007-04-23 |  | 2007-04-16 | 2007-04-23 | 6d | 156d | 0d | start no earlier than 2007-04-16 |
| 49 | To skirting size 300*100*6 mm thick | 5d | 2007-04-24 | 2007-04-30 | 48 | 2007-04-24 | 2007-04-30 | 5d | 156d | 0d |  |
| 50 | Imported Spanish Ceramic, To kitchens floors size 400*400*9 mm thick | 5d | 2007-05-01 | 2007-05-07 | 49 | 2007-05-01 | 2007-05-07 | 5d | 156d | 0d |  |
| 51 | Ditto but EMIRATES R.A.K ceramic, To floors, size 300*300*9 mm thick for maids rooms | 2d | 2007-05-08 | 2007-05-09 | 50 | 2007-05-08 | 2007-05-09 | 2d | 156d | 0d |  |
| 52 | To skirting, size 300*100*6 mm thick for maids rooms | 3d | 2007-05-10 | 2007-05-14 | 51 | 2007-05-10 | 2007-05-14 | 3d | 156d | 0d |  |
| 53 | Ditto but local ceramic for boiler and maids bathrooms 200*200*9 mm | 6d | 2007-05-15 | 2007-05-22 | 52 | 2007-05-15 | 2007-05-22 | 6d | 156d |  |  |
| 54 | One piece JERUSALEM stone to steps, to treads and risers | 4d | 2007-05-07 | 2007-05-10 | 45 | 2007-05-07 | 2007-05-10 | 4d | 153d | 0d |  |
| 55 | Skirting to flights 6 mm thick | 4d | 2007-05-11 | 2007-05-16 | 54 | 2007-05-11 | 2007-05-16 | 4d | 153d | 0d |  |
| 56 | One piece gravelled tiles to external steps, to treads and risers | 3d | 2007-05-17 | 2007-05-21 | 55 | 2007-05-17 | 2007-05-21 | 3d | 153d | 0d |  |
| 57 | Skirting to flights 6 mm thick | 4d | 2007-05-22 | 2007-05-25 | 56 | 2007-05-22 | 2007-05-25 | 4d | 153d |  |  |
| 58 | Precast interlock concrete cement floor tiles, to walkway at parking and ramps size 400*400*40 mm | 12d | 2007-12-03 | 2007-12-18 |  | 2007-12-03 | 2007-12-18 | 12d | 6d |  | start no earlier than 2007-12-03 |
| 59 | Standby itme ditto but basalt stone | 10d | 2007-12-03 | 2007-12-14 |  | 2007-12-03 | 2007-12-14 | 10d | 64d | 0d | start no earlier than 2007-12-03 |
| 60 | Precast concrete cement floor tiles, for external paving | 8d | 2007-12-17 | 2007-12-26 | 59 | 2007-12-17 | 2007-12-26 | 8d | 64d |  |  |
| 61 | Three coats cement and sand (1:4) plastereing, smooth finish, To walls, Internally | 97d | 2007-04-02 | 2007-08-14 |  | 2007-04-02 | 2007-08-14 | 97d | 96d |  | start no earlier than 2007-04-02 |
| 62 | To walls, Internally behind ceramic walls | 28d | 2007-05-02 | 2007-06-08 |  | 2007-05-02 | 2007-06-08 | 28d | 143d |  | start no earlier than 2007-05-02 |
| 63 | To walls, internlly for water tanks walls | 9d | 2007-04-02 | 2007-04-12 |  | 2007-04-02 | 2007-04-12 | 9d | 184d |  | start no earlier than 2007-04-02 |
| 64 | To walls, Externally | 10d | 2007-05-02 | 2007-05-15 |  | 2007-05-02 | 2007-05-15 | 10d | 161d |  | start no earlier than 2007-05-02 |
| 65 | Glazed imported SPANISH ceramic coloured wall tiles, to walls size 300*300*9 mm thick for bath rooms | 8d | 2007-05-23 | 2007-06-01 | 53 | 2007-05-23 | 2007-06-01 | 8d | 207d | 0d |  |
| 66 | Ditto but to walls size 100*100*9 mm thick mosaic for kitchens | 7d | 2007-05-23 | 2007-05-31 |  | 2007-05-23 | 2007-05-31 | 7d | 213d |  | start no earlier than 2007-05-23 |
| 67 | Ditto but JERUSALEM wall tiles for basement 1 entrance complete | 4d | 2007-05-23 | 2007-05-28 |  | 2007-05-23 | 2007-05-28 | 4d | 216d |  | start no earlier than 2007-05-23 |
| 68 | Ditto but local glazed colored ceramic wall tiles, To walls size 200*200*8 mm thick for Boiler | 5d | 2007-06-04 | 2007-06-08 | 65 | 2007-06-04 | 2007-06-08 | 5d | 207d |  |  |
| 69 | To walls size 200*200*8 mm thick for maids rooms (white colour) | 4d | 2007-06-04 | 2007-06-07 |  | 2007-06-04 | 2007-06-07 | 4d | 208d |  | start no earlier than 2007-06-04 |
| 70 | Ceiling finishes,Three coats cement and sand (1:4) plastering, smooth finish | 34d | 2007-07-09 | 2007-08-23 |  | 2007-07-09 | 2007-08-23 | 34d | 153d |  | start no earlier than 2007-07-09 |

| ID | Task | Duration | Start | Finish | Predecessors | Baseline start | Baseline finish | Baseline duration | Total slack | Free slack | Constraint |
| --- | --- | --- | --- | --- | --- | --- | --- | --- | --- | --- | --- |
| 71 | JERUSALEM stone cladding, fixed to faces of concrete with 30 mm thick with cement mortar for parking columns | 7d | 2008-01-02 | 2008-01-10 |  | 2008-01-02 | 2008-01-10 | 7d | 41d | 0d | start no earlier than 2008-01-02 |
| 72 | JERUSALEM stone cladding, for main entrances | 5d | 2008-01-11 | 2008-01-17 | 71 | 2008-01-11 | 2008-01-17 | 5d | 41d | 0d |  |
| 73 | AJLOON stone cladding, for parking walls and entrance | 7d | 2008-01-18 | 2008-01-28 | 72 | 2008-01-18 | 2008-01-28 | 7d | 41d |  |  |
| 74 | Suspended ceilings, 12 mm thick gypsum board suspended ceiling panels finished with skim coat, including conceled galvanized suspension system, stepped decorations, strips, for different sevices | 4d | 2008-02-01 | 2008-02-06 |  | 2008-02-01 | 2008-02-06 | 4d | 34d |  | start no earlier than 2008-02-01 |
| 75 | 800mm*300 mm height gypsum cornice suspended finished with skim coat, for saloons, TV and dinning ceilings | 28d | 2008-02-01 | 2008-03-11 |  | 2008-02-01 | 2008-03-11 | 28d | 10d |  | start no earlier than 2008-02-01 |
| 76 | Internally Emulsion PVA-based paint matt finish for interior, To walls | 70d | 2007-08-01 | 2007-11-06 |  | 2007-08-01 | 2007-11-06 | 70d | 80d | 0d | start no earlier than 2007-08-01 |
| 77 | Externally, Resin base water proofing acrylic textured decorative coating, to exterior walls | 25d | 2007-05-21 | 2007-06-22 |  | 2007-05-21 | 2007-06-22 | 25d | 197d |  | start no earlier than 2007-05-21 |
| 78 | To walls at roof | 17d | 2007-08-01 | 2007-08-23 |  | 2007-08-01 | 2007-08-23 | 17d | 153d |  | start no earlier than 2007-08-01 |
| 79 | Non- toxic epoxy paint including primer all as specified, complete to floor, walls and ceiling of water tanks | 20d | 2007-05-16 | 2007-06-12 | 64 | 2007-05-16 | 2007-06-12 | 20d | 205d |  |  |
| 80 | CORNER GUARDS, supply and fix rubber corner guards for columns at parking areas, 100*100 mm, 1200 mm height | 8d | 2007-08-01 | 2007-08-10 |  | 2007-08-01 | 2007-08-10 | 8d | 162d |  | start no earlier than 2007-08-01 |
| 81 | Mirrors, 6 mm thick mirrors with 20 mm stainless steel frame including 8 mm thick plywood backing, size 1050*2600 mm high | 3d | 2007-11-30 | 2007-12-04 |  | 2007-11-30 | 2007-12-04 | 3d | 52d | 0d | start no earlier than 2007-11-30 |
| 82 | size 1600*1300 mm high | 5d | 2007-12-05 | 2007-12-11 | 81 | 2007-12-05 | 2007-12-11 | 5d | 52d | 0d |  |
| 83 | Size 800*1300 mm high | 10d | 2007-12-12 | 2007-12-25 | 82 | 2007-12-12 | 2007-12-25 | 10d | 52d | 0d |  |
| 84 | Local KARAK Marble countertop 30 mm thick with molding wash basin including 200 mm dropped cornice, size 1700*600 mm wide | 2d | 2007-12-26 | 2007-12-27 | 83 | 2007-12-26 | 2007-12-27 | 2d | 52d | 0d |  |
| 85 | Size 2800*600 mm wide | 1d | 2007-12-28 | 2007-12-28 | 84 | 2007-12-28 | 2007-12-28 | 1d | 52d | 0d |  |
| 86 | Size 2000*600 mm wide | 1d | 2007-12-31 | 2007-12-31 | 85 | 2007-12-31 | 2007-12-31 | 1d | 52d | 0d |  |
| 87 | Size 1800*600 mm wide | 1d | 2008-01-01 | 2008-01-01 | 86 | 2008-01-01 | 2008-01-01 | 1d | 52d | 0d |  |
| 88 | Size 1200*600 mm wide | 2d | 2008-01-02 | 2008-01-03 | 87 | 2008-01-02 | 2008-01-03 | 2d | 52d | 0d |  |
| 89 | Size 2200*600 mm wide | 2d | 2008-01-04 | 2008-01-07 | 88 | 2008-01-04 | 2008-01-07 | 2d | 52d | 0d |  |
| 90 | Size 1900*600 mm wide | 3d | 2008-01-08 | 2008-01-10 | 89 | 2008-01-08 | 2008-01-10 | 3d | 52d | 0d |  |
| 91 | Size 2600*600 mm wide | 1d | 2008-01-11 | 2008-01-11 | 90 | 2008-01-11 | 2008-01-11 | 1d | 52d |  |  |
| 92 | Planting, Agricultural soil of clean selected top soil suitable for planting purposes | 22d | 2008-02-18 | 2008-03-18 |  | 2008-02-18 | 2008-03-18 | 22d | 0d |  | start no earlier than 2008-02-18 |
| 93 | Slab on grade, 100 mm thick, to building | 4d | 2007-03-02 | 2007-03-07 | 5 | 2007-03-02 | 2007-03-07 | 4d | 274d |  |  |
