Schedule from MS Project, 2006-12-22 to 2008-03-27.
alanzy company

## Calendars

- Standard: Mon-Fri 08:00-12:00, 13:00-17:00; Sat-Sun off.

## Schedule

| ID | Task | Duration | Start | Finish | Predecessors | Baseline start | Baseline finish | Baseline duration | Total slack | Free slack | Constraint |
| --- | --- | --- | --- | --- | --- | --- | --- | --- | --- | --- | --- |
| 1 | Excavation to foundations level [Contractor #5 Eng. Baker Alnabulsi] | 9d | 2006-12-22 | 2007-01-03 |  | 2006-12-22 | 2007-01-02 | 8d | 168d | 0d |  |
| 2 | Excavation for external works | 7d | 2006-12-22 | 2007-01-01 |  | 2006-12-22 | 2007-01-01 | 7d | 300d | 0d |  |
| 3 | Approved filling inside | 10d | 2007-02-16 | 2007-03-01 | 11 | 2007-02-16 | 2007-03-01 | 10d | 267d | 0d |  |
| 4 | Approved filling outside | 10d | 2007-02-26 | 2007-03-09 | 13 | 2007-02-26 | 2007-03-09 | 10d | 271d |  |  |
| 5 | Crushed aggregate base 200 mm thick inside building | 6d | 2007-03-02 | 2007-03-09 | 3 | 2007-03-02 | 2007-03-09 | 6d | 267d | 0d |  |
| 6 | Blinding 100 mm thick under foundations and tie beams | 5d | 2007-01-04 | 2007-01-10 | 1 | 2007-01-04 | 2007-01-10 | 5d | 168d | 0d |  |
| 7 | Blinding 50 mm thick under slabs on grade | 4d | 2007-02-26 | 2007-03-01 |  | 2007-02-26 | 2007-03-01 | 4d | 271d | 0d | start no earlier than 2007-02-26 |
| 8 | Blinding 100 mm thick under external works | 10d | 2007-01-02 | 2007-01-15 | 2 | 2007-01-02 | 2007-01-15 | 10d | 300d | 6d |  |
| 9 | Reinforced concrete for foundations | 10d | 2007-01-15 | 2007-01-26 |  | 2007-01-15 | 2007-01-26 | 10d | 301d |  | start no earlier than 2007-01-15 |
| 10 | Reinforced concrete for tie beams | 8d | 2007-05-04 | 2007-05-15 | 35 | 2007-05-04 | 2007-05-15 | 8d | 224d |  |  |
| 11 | Reinforced concrete for columns & column necks | 5d | 2007-02-09 | 2007-02-15 |  | 2007-02-09 | 2007-02-15 | 5d | 267d | 0d | start no earlier than 2007-02-09 |
| 12 | Reinforced concrete for slab on grade, 100 mm thick to external pavements | 6d | 2007-03-02 | 2007-03-09 | 7 | 2007-03-02 | 2007-03-09 | 6d | 271d |  |  |
| 13 | Reinforced concrete for external basement walls | 20d | 2007-01-29 | 2007-02-23 |  | 2007-01-29 | 2007-02-23 | 20d | 271d | 0d | start no earlier than 2007-01-29 |
| 14 | Reinforced concrete for water tank walls | 10d | 2007-01-24 | 2007-02-06 | 8 | 2007-01-24 | 2007-02-06 | 10d | 294d |  | start no earlier than 2007-01-24 |
| 15 | Reinforced concrete for external foundations | 8d | 2007-01-15 | 2007-01-24 |  | 2007-01-15 | 2007-01-24 | 8d | 289d | 0d | start no earlier than 2007-01-15 |
| 16 | Reinforced concrete for external walls | 14d | 2007-01-25 | 2007-02-13 | 15 | 2007-01-25 | 2007-02-13 | 14d | 289d |  |  |
| 17 | Reinforced concrete behind stone elevations | 160d | 2007-03-01 | 2007-10-10 |  | 2007-03-01 | 2007-10-10 | 160d | 118d |  | start no earlier than 2007-03-01 |
| 18 | Reinforced concrete for ribbed slabs, 310 mm thick | 140d | 2007-03-07 | 2007-09-18 |  | 2007-03-07 | 2007-09-18 | 140d | 134d |  | start no earlier than 2007-03-07 |
| 19 | Reinforced concrete for stair cases (steps & flights) inside | 135d | 2007-03-07 | 2007-09-11 |  | 2007-03-07 | 2007-09-11 | 135d | 139d |  | start no earlier than 2007-03-07 |
| 20 | Reinforced concrete for stair cases (steps & flights) outside | 18d | 2007-11-02 | 2007-11-27 | 76 | 2007-11-07 | 2007-11-30 | 18d | 87d |  | start no earlier than 2007-04-09 |
| 21 | Deformed high yield steel bar reinforcement for various diameters, generally | 145d | 2007-01-11 | 2007-08-01 | 6 | 2007-01-11 | 2007-08-01 | 145d | 168d |  |  |
| 22 | Smooth mild steel bar reinforcement for Y8 mm | 145d | 2007-01-09 | 2007-07-30 |  | 2007-01-09 | 2007-07-30 | 145d | 170d |  | start no earlier than 2007-01-09 |
| 23 | Hollow concrete blocks for walls, 100 mm thick | 160d | 2007-03-15 | 2007-10-24 |  | 2007-03-15 | 2007-10-24 | 160d | 108d |  | start no earlier than 2007-03-15 |
| 24 | Hollow concrete blocks for walls, 150 mm thick | 160d | 2007-03-15 | 2007-10-24 |  | 2007-03-15 | 2007-10-24 | 160d | 108d |  | start no earlier than 2007-03-15 |
| 25 | Hollow concrete blocks for walls, 200 mm thick | 160d | 2007-03-15 | 2007-10-24 |  | 2007-03-15 | 2007-10-24 | 160d | 108d |  | start no earlier than 2007-03-15 |
| 26 | Hollow concrete rib blocks | 160d | 2007-03-01 | 2007-10-10 |  | 2007-03-01 | 2007-10-10 | 160d | 118d |  | start no earlier than 2007-03-01 |
| 27 | concrete blocks, 100 mm thick for external walls of basement | 30d | 2007-03-15 | 2007-04-25 |  | 2007-03-15 | 2007-04-25 | 30d | 238d |  | start no earlier than 2007-03-15 |
| 28 | concrete blocks, 100 mm thick, behind the stone walls | 160d | 2007-02-22 | 2007-10-03 |  | 2007-02-22 | 2007-10-03 | 160d | 123d |  | start no earlier than 2007-02-22 |
| 29 | Foam concrete, to roofs | 7d | 2007-09-25 | 2007-10-03 |  | 2007-09-25 | 2007-10-03 | 7d | 113d | 0d | start no earlier than 2007-09-25 |
| 30 | Cement sand screed, to roofs | 10d | 2007-10-04 | 2007-10-17 | 29 | 2007-10-04 | 2007-10-17 | 10d | 113d |  |  |
| 31 | 4 mm thick torch applied modified bituminous water-proofing membrane | 12d | 2007-10-22 | 2007-11-06 |  | 2007-10-22 | 2007-11-06 | 12d | 99d |  | start no earlier than 2007-10-22 |
| 32 | 4 mm thick torch applied modified bituminous polymer water-proofing membrane, for slabs on grade | 12d | 2007-04-09 | 2007-04-24 |  | 2007-04-09 | 2007-04-24 | 12d | 239d |  | start no earlier than 2007-04-09 |
| 33 | 4 mm thick torch applied modified bituminous polymer water-proofing membrane, to basement walls | 25d | 2007-02-22 | 2007-03-28 |  | 2007-02-22 | 2007-03-28 | 25d | 258d |  | start no earlier than 2007-02-22 |
| 34 | Pvc water stop for water tank walls | 4d | 2008-03-24 | 2008-03-27 | 92 | 2008-03-19 | 2008-03-24 | 4d | 0d |  |  |
| 35 | Damp proofing membrane to basement walls | 25d | 2007-03-30 | 2007-05-03 |  | 2007-03-30 | 2007-05-03 | 25d | 224d | 0d | start no earlier than 2007-03-30 |
| 36 | Local ajlon stone, case 1 mechanical push | 160d | 2007-02-15 | 2007-09-26 |  | 2007-02-15 | 2007-09-26 | 160d | 128d |  | start no earlier than 2007-02-15 |
| 37 | Local ajlon stone, case 2 light chisled face finish | 160d | 2007-02-15 | 2007-09-26 |  | 2007-02-15 | 2007-09-26 | 160d | 128d |  | start no earlier than 2007-02-15 |
| 38 | Local ajlon stone, case 3 rough chirled face finish | 160d | 2007-02-15 | 2007-09-26 |  | 2007-02-15 | 2007-09-26 | 160d | 128d |  | start no earlier than 2007-02-15 |
| 39 | Local ajlon stone, case 4 face finish | 160d | 2007-02-15 | 2007-09-26 |  | 2007-02-15 | 2007-09-26 | 160d | 128d |  | start no earlier than 2007-02-15 |
| 40 | Stone coping local ajlon | 16d | 2007-09-18 | 2007-10-09 |  | 2007-09-18 | 2007-10-09 | 16d | 119d |  | start no earlier than 2007-09-18 |
| 41 | Approved first quality karak marble grey color | 160d | 2007-04-16 | 2007-11-23 |  | 2007-04-16 | 2007-11-23 | 160d | 86d |  | start no earlier than 2007-04-16 |
| 42 | Ajlon cornice stone to walls | 40d | 2007-05-01 | 2007-06-25 |  | 2007-05-01 | 2007-06-25 | 40d | 195d |  | start no earlier than 2007-05-01 |
| 43 | Precast terrazzo tiles, to floors, size 400*100*30 mm for guards rooms | 4d | 2007-04-16 | 2007-04-19 |  | 2007-04-16 | 2007-04-20 | 5d | 242d |  | start no earlier than 2007-04-16 |
| 44 | Approved first quality JERUSALEM stone, to floors of saloons, living, Tv and master bedrooms areas 600*600*20 mm thick | 8d | 2007-04-16 | 2007-04-25 |  | 2007-04-16 | 2007-04-26 | 9d | 217d | 0d | start no earlier than 2007-04-16 |
| 45 | To skirting size 600*100*6 mm thick | 5d | 2007-04-26 | 2007-05-02 | 44 | 2007-04-27 | 2007-05-04 | 6d | 217d | 0d |  |
| 46 | (STAND BY ITEM) DITTO BUT ITALIAN MARBLE, to floors of saloons, living, TV and master bedrooms areas 600*600*20 mm thick | 5d | 2007-04-16 | 2007-04-20 |  | 2007-04-16 | 2007-04-19 | 4d | 237d | 0d | start no earlier than 2007-04-16 |
| 47 | To skirting size 600*100*6 mm thick | 4d | 2007-04-23 | 2007-04-26 | 46 | 2007-04-20 | 2007-04-24 | 3d | 237d |  |  |
| 48 | Ditto but Omani or stone like ceramic tiles, to floors 400*400*20 mm thick | 4d | 2007-04-16 | 2007-04-19 |  | 2007-04-16 | 2007-04-23 | 6d | 207d | 0d | start no earlier than 2007-04-16 |
| 49 | To skirting size 300*100*6 mm thick | 3d | 2007-04-20 | 2007-04-24 | 48 | 2007-04-24 | 2007-04-30 | 5d | 207d | 0d |  |
| 50 | Imported Spanish Ceramic, To kitchens floors size 400*400*9 mm thick | 7d | 2007-04-25 | 2007-05-03 | 49 | 2007-05-01 | 2007-05-07 | 5d | 207d | 0d |  |
| 51 | Ditto but EMIRATES R.A.K ceramic, To floors, size 300*300*9 mm thick for maids rooms | 3d | 2007-05-04 | 2007-05-08 | 50 | 2007-05-08 | 2007-05-09 | 2d | 207d | 0d |  |
| 52 | To skirting, size 300*100*6 mm thick for maids rooms | 2d | 2007-05-09 | 2007-05-10 | 51 | 2007-05-10 | 2007-05-14 | 3d | 207d | 0d |  |
| 53 | Ditto but local ceramic for boiler and maids bathrooms 200*200*9 mm | 5d | 2007-05-11 | 2007-05-17 | 52 | 2007-05-15 | 2007-05-22 | 6d | 207d | 0d |  |
| 54 | One piece JERUSALEM stone to steps, to treads and risers | 5d | 2007-05-03 | 2007-05-09 | 45 | 2007-05-07 | 2007-05-10 | 4d | 217d | 0d |  |
| 55 | Skirting to flights 6 mm thick | 3d | 2007-05-10 | 2007-05-14 | 54 | 2007-05-11 | 2007-05-16 | 4d | 217d | 0d |  |
| 56 | One piece gravelled tiles to external steps, to treads and risers | 5d | 2007-05-15 | 2007-05-21 | 55 | 2007-05-17 | 2007-05-21 | 3d | 217d | 0d |  |
| 57 | Skirting to flights 6 mm thick | 3d | 2007-05-22 | 2007-05-24 | 56 | 2007-05-22 | 2007-05-25 | 4d | 217d |  |  |
| 58 | Precast interlock concrete cement floor tiles, to walkway at parking and ramps size 400*400*40 mm | 10d | 2007-12-03 | 2007-12-14 |  | 2007-12-03 | 2007-12-18 | 12d | 71d |  | start no earlier than 2007-12-03 |
| 59 | Standby itme ditto but basalt stone | 13d | 2007-12-03 | 2007-12-19 |  | 2007-12-03 | 2007-12-14 | 10d | 58d | 0d | start no earlier than 2007-12-03 |
| 60 | Precast concrete cement floor tiles, for external paving | 10d | 2007-12-20 | 2008-01-02 | 59 | 2007-12-17 | 2007-12-26 | 8d | 58d |  |  |
| 61 | Three coats cement and sand (1:4) plastereing, smooth finish, To walls, Internally | 100d | 2007-04-02 | 2007-08-17 |  | 2007-04-02 | 2007-08-14 | 97d | 156d |  | start no earlier than 2007-04-02 |
| 62 | To walls, Internally behind ceramic walls | 30d | 2007-05-02 | 2007-06-12 |  | 2007-05-02 | 2007-06-08 | 28d | 204d |  | start no earlier than 2007-05-02 |
| 63 | To walls, internlly for water tanks walls | 10d | 2007-04-02 | 2007-04-13 |  | 2007-04-02 | 2007-04-12 | 9d | 246d |  | start no earlier than 2007-04-02 |
| 64 | To walls, Externally | 9d | 2007-05-02 | 2007-05-14 |  | 2007-05-02 | 2007-05-15 | 10d | 205d | 0d | start no earlier than 2007-05-02 |
| 65 | Glazed imported SPANISH ceramic coloured wall tiles, to walls size 300*300*9 mm thick for bath rooms | 9d | 2007-05-18 | 2007-05-30 | 53 | 2007-05-23 | 2007-06-01 | 8d | 207d | 0d |  |
| 66 | Ditto but to walls size 100*100*9 mm thick mosaic for kitchens | 8d | 2007-05-23 | 2007-06-01 |  | 2007-05-23 | 2007-05-31 | 7d | 211d |  | start no earlier than 2007-05-23 |
| 67 | Ditto but JERUSALEM wall tiles for basement 1 entrance complete | 3d | 2007-05-23 | 2007-05-25 |  | 2007-05-23 | 2007-05-28 | 4d | 216d |  | start no earlier than 2007-05-23 |
| 68 | Ditto but local glazed colored ceramic wall tiles, To walls size 200*200*8 mm thick for Boiler | 6d | 2007-05-31 | 2007-06-07 | 65 | 2007-06-04 | 2007-06-08 | 5d | 207d |  |  |
| 69 | To walls size 200*200*8 mm thick for maids rooms (white colour) | 5d | 2007-06-04 | 2007-06-08 |  | 2007-06-04 | 2007-06-07 | 4d | 206d |  | start no earlier than 2007-06-04 |
| 70 | Ceiling finishes,Three coats cement and sand (1:4) plastering, smooth finish | 35d | 2007-07-09 | 2007-08-24 |  | 2007-07-09 | 2007-08-23 | 34d | 151d |  | start no earlier than 2007-07-09 |

| ID | Task | Duration | Start | Finish | Predecessors | Baseline start | Baseline finish | Baseline duration | Total slack | Free slack | Constraint |
| --- | --- | --- | --- | --- | --- | --- | --- | --- | --- | --- | --- |
| 71 | JERUSALEM stone cladding, fixed to faces of concrete with 30 mm thick with cement mortar for parking columns | 6d | 2008-01-02 | 2008-01-09 |  | 2008-01-02 | 2008-01-10 | 7d | 41d | 0d | start no earlier than 2008-01-02 |
| 72 | JERUSALEM stone cladding, for main entrances | 4d | 2008-01-10 | 2008-01-15 | 71 | 2008-01-11 | 2008-01-17 | 5d | 41d | 0d |  |
| 73 | AJLOON stone cladding, for parking walls and entrance | 8d | 2008-01-16 | 2008-01-25 | 72 | 2008-01-18 | 2008-01-28 | 7d | 41d |  |  |
| 74 | Suspended ceilings, 12 mm thick gypsum board suspended ceiling panels finished with skim coat, including conceled galvanized suspension system, stepped decorations, strips, for different sevices | 5d | 2008-02-01 | 2008-02-07 |  | 2008-02-01 | 2008-02-06 | 4d | 32d |  | start no earlier than 2008-02-01 |
| 75 | 800mm*300 mm height gypsum cornice suspended finished with skim coat, for saloons, TV and dinning ceilings | 30d | 2008-02-01 | 2008-03-13 |  | 2008-02-01 | 2008-03-11 | 28d | 7d |  | start no earlier than 2008-02-01 |
| 76 | Internally Emulsion PVA-based paint matt finish for interior, To walls | 67d | 2007-08-01 | 2007-11-01 |  | 2007-08-01 | 2007-11-06 | 70d | 87d | 0d | start no earlier than 2007-08-01 |
| 77 | Externally, Resin base water proofing acrylic textured decorative coating, to exterior walls | 21d | 2007-05-21 | 2007-06-18 |  | 2007-05-21 | 2007-06-22 | 25d | 203d |  | start no earlier than 2007-05-21 |
| 78 | To walls at roof | 18d | 2007-08-01 | 2007-08-24 |  | 2007-08-01 | 2007-08-23 | 17d | 154d |  | start no earlier than 2007-08-01 |
| 79 | Non- toxic epoxy paint including primer all as specified, complete to floor, walls and ceiling of water tanks | 24d | 2007-05-15 | 2007-06-15 | 64 | 2007-05-16 | 2007-06-12 | 20d | 204d |  |  |
| 80 | CORNER GUARDS, supply and fix rubber corner guards for columns at parking areas, 100*100 mm, 1200 mm height | 8d | 2007-08-01 | 2007-08-10 |  | 2007-08-01 | 2007-08-10 | 8d | 161d |  | start no earlier than 2007-08-01 |
| 81 | Mirrors, 6 mm thick mirrors with 20 mm stainless steel frame including 8 mm thick plywood backing, size 1050*2600 mm high | 5d | 2007-11-30 | 2007-12-06 |  | 2007-11-30 | 2007-12-04 | 3d | 53d | 0d | start no earlier than 2007-11-30 |
| 82 | size 1600*1300 mm high | 4d | 2007-12-07 | 2007-12-12 | 81 | 2007-12-05 | 2007-12-11 | 5d | 53d | 0d |  |
| 83 | Size 800*1300 mm high | 10d | 2007-12-13 | 2007-12-26 | 82 | 2007-12-12 | 2007-12-25 | 10d | 53d | 0d |  |
| 84 | Local KARAK Marble countertop 30 mm thick with molding wash basin including 200 mm dropped cornice, size 1700*600 mm wide | 2d | 2007-12-27 | 2007-12-28 | 83 | 2007-12-26 | 2007-12-27 | 2d | 53d | 0d |  |
| 85 | Size 2800*600 mm wide | 1d | 2007-12-31 | 2007-12-31 | 84 | 2007-12-28 | 2007-12-28 | 1d | 53d | 0d |  |
| 86 | Size 2000*600 mm wide | 1d | 2008-01-01 | 2008-01-01 | 85 | 2007-12-31 | 2007-12-31 | 1d | 53d | 0d |  |
| 87 | Size 1800*600 mm wide | 1d | 2008-01-02 | 2008-01-02 | 86 | 2008-01-01 | 2008-01-01 | 1d | 53d | 0d |  |
| 88 | Size 1200*600 mm wide | 2d | 2008-01-03 | 2008-01-04 | 87 | 2008-01-02 | 2008-01-03 | 2d | 53d | 0d |  |
| 89 | Size 2200*600 mm wide | 2d | 2008-01-07 | 2008-01-08 | 88 | 2008-01-04 | 2008-01-07 | 2d | 53d | 0d |  |
| 90 | Size 1900*600 mm wide | 3d | 2008-01-09 | 2008-01-11 | 89 | 2008-01-08 | 2008-01-10 | 3d | 53d | 0d |  |
| 91 | Size 2600*600 mm wide | 1d | 2008-01-14 | 2008-01-14 | 90 | 2008-01-11 | 2008-01-11 | 1d | 53d |  |  |
| 92 | Planting, Agricultural soil of clean selected top soil suitable for planting purposes | 25d | 2008-02-18 | 2008-03-21 |  | 2008-02-18 | 2008-03-18 | 22d | 0d |  | start no earlier than 2008-02-18 |
| 93 | Slab on grade, 100 mm thick, to building | 4d | 2007-03-12 | 2007-03-15 | 5 | 2007-03-12 | 2007-03-15 | 4d | 267d |  |  |
