Schedule from MS Project, 2006-12-22 to 2008-03-24.
alanzy company

## Calendars

- Standard: Mon-Fri 08:00-12:00, 13:00-17:00; Sat-Sun off.

## Schedule

| ID | Task | Duration | Start | Finish | Predecessors | Baseline start | Baseline finish | Baseline duration | Total slack | Free slack | Constraint |
| --- | --- | --- | --- | --- | --- | --- | --- | --- | --- | --- | --- |
| 1 | Excavation to foundations level [Contractor #6 Eng. Yousif Hussein Saleh] | 8d | 2006-12-22 | 2007-01-02 |  | 2006-12-22 | 2007-01-02 | 8d | 47d | 0d |  |
| 2 | Excavation for external works | 5d | 2006-12-22 | 2006-12-28 |  |  |  |  | 7d | 0d |  |
| 3 | Approved filling inside | 7d | 2007-02-15 | 2007-02-23 | 11 |  |  |  | 112d | 0d |  |
| 4 | Approved filling outside | 7d | 2007-02-19 | 2007-02-27 | 13 |  |  |  | 114d |  |  |
| 5 | Crushed aggregate base 200 mm thick inside building | 4d | 2007-02-26 | 2007-03-01 | 3 |  |  |  | 112d |  |  |
| 6 | Blinding 100 mm thick under foundations and tie beams | 4d | 2007-01-03 | 2007-01-08 | 1 |  |  |  | 47d | 0d |  |
| 7 | Blinding 50 mm thick under slabs on grade | 3d | 2007-02-26 | 2007-02-28 |  |  |  |  | 113d |  | start no earlier than 2007-02-26 |
| 8 | Blinding 100 mm thick under external works | 8d | 2006-12-29 | 2007-01-09 | 2 |  |  |  | 149d |  |  |
| 9 | Reinforced concrete for foundations | 8d | 2007-01-15 | 2007-01-24 |  |  |  |  | 138d |  | start no earlier than 2007-01-15 |
| 10 | Reinforced concrete for tie beams | 6d | 2007-05-02 | 2007-05-09 | 35 |  |  |  | 228d |  |  |
| 11 | Reinforced concrete for columns & column necks | 4d | 2007-02-09 | 2007-02-14 |  |  |  |  | 112d | 0d | start no earlier than 2007-02-09 |
| 12 | Reinforced concrete for slab on grade, 100 mm thick to external pavements | 5d | 2007-03-01 | 2007-03-07 | 7 |  |  |  | 108d |  |  |
| 13 | Reinforced concrete for external basement walls | 15d | 2007-01-29 | 2007-02-16 |  |  |  |  | 114d | 0d | start no earlier than 2007-01-29 |
| 14 | Reinforced concrete for water tank walls | 8d | 2007-01-24 | 2007-02-02 | 8 |  |  |  | 178d |  | start no earlier than 2007-01-24 |
| 15 | Reinforced concrete for external foundations | 7d | 2007-01-15 | 2007-01-23 |  |  |  |  | 289d | 0d | start no earlier than 2007-01-15 |
| 16 | Reinforced concrete for external walls | 15d | 2007-01-24 | 2007-02-13 | 15 |  |  |  | 171d |  |  |
| 17 | Reinforced concrete behind stone elevations | 150d | 2007-03-01 | 2007-09-26 |  |  |  |  | 10d |  | start no earlier than 2007-03-01 |
| 18 | Reinforced concrete for ribbed slabs, 310 mm thick | 130d | 2007-03-07 | 2007-09-04 |  |  |  |  | 26d |  | start no earlier than 2007-03-07 |
| 19 | Reinforced concrete for stair cases (steps & flights) inside | 130d | 2007-03-07 | 2007-09-04 |  |  |  |  | 26d |  | start no earlier than 2007-03-07 |
| 20 | Reinforced concrete for stair cases (steps & flights) outside | 20d | 2007-10-24 | 2007-11-20 | 76 |  |  |  | 89d |  | start no earlier than 2007-04-09 |
| 21 | Deformed high yield steel bar reinforcement for various diameters, generally | 150d | 2007-01-09 | 2007-08-06 | 6 |  |  |  | 47d |  |  |
| 22 | Smooth mild steel bar reinforcement for Y8 mm | 150d | 2007-01-09 | 2007-08-06 |  |  |  |  | 47d |  | start no earlier than 2007-01-09 |
| 23 | Hollow concrete blocks for walls, 100 mm thick | 20d | 2007-03-15 | 2007-04-11 |  |  |  |  | 248d |  | start no earlier than 2007-03-15 |
| 24 | Hollow concrete blocks for walls, 150 mm thick | 9d | 2007-03-15 | 2007-03-27 |  |  |  |  | 259d |  | start no earlier than 2007-03-15 |
| 25 | Hollow concrete blocks for walls, 200 mm thick | 5d | 2007-03-15 | 2007-03-21 |  |  |  |  | 263d |  | start no earlier than 2007-03-15 |
| 26 | Hollow concrete rib blocks | 15d | 2007-03-01 | 2007-03-21 |  |  |  |  | 263d |  | start no earlier than 2007-03-01 |
| 27 | concrete blocks, 100 mm thick for external walls of basement | 18d | 2007-03-15 | 2007-04-09 |  |  |  |  | 250d |  | start no earlier than 2007-03-15 |
| 28 | concrete blocks, 100 mm thick, behind the stone walls | 25d | 2007-02-22 | 2007-03-28 |  |  |  |  | 258d |  | start no earlier than 2007-02-22 |
| 29 | Foam concrete, to roofs | 9d | 2007-09-25 | 2007-10-05 |  |  |  |  | 110d | 0d | start no earlier than 2007-09-25 |
| 30 | Cement sand screed, to roofs | 11d | 2007-10-08 | 2007-10-22 | 29 |  |  |  | 110d |  |  |
| 31 | 4 mm thick torch applied modified bituminous water-proofing membrane | 9d | 2007-10-22 | 2007-11-01 |  |  |  |  | 102d |  | start no earlier than 2007-10-22 |
| 32 | 4 mm thick torch applied modified bituminous polymer water-proofing membrane, for slabs on grade | 11d | 2007-04-09 | 2007-04-23 |  |  |  |  | 240d |  | start no earlier than 2007-04-09 |
| 33 | 4 mm thick torch applied modified bituminous polymer water-proofing membrane, to basement walls | 22d | 2007-02-22 | 2007-03-23 |  |  |  |  | 261d |  | start no earlier than 2007-02-22 |
| 34 | Pvc water stop for water tank walls | 3d | 2008-03-20 | 2008-03-24 | 92 |  |  |  | 0d |  |  |
| 35 | Damp proofing membrane to basement walls | 23d | 2007-03-30 | 2007-05-01 |  |  |  |  | 228d | 0d | start no earlier than 2007-03-30 |
| 36 | Local ajlon stone, case 1 mechanical push | 150d | 2007-02-15 | 2007-09-12 |  |  |  |  | 75d |  | start no earlier than 2007-02-15 |
| 37 | Local ajlon stone, case 2 light chisled face finish | 150d | 2007-02-15 | 2007-09-12 |  |  |  |  | 75d |  | start no earlier than 2007-02-15 |
| 38 | Local ajlon stone, case 3 rough chirled face finish | 150d | 2007-02-15 | 2007-09-12 |  |  |  |  | 75d |  | start no earlier than 2007-02-15 |
| 39 | Local ajlon stone, case 4 face finish | 150d | 2007-02-15 | 2007-09-12 |  |  |  |  | 75d |  | start no earlier than 2007-02-15 |
| 40 | Stone coping local ajlon | 30d | 2007-09-18 | 2007-10-29 |  |  |  |  | 105d |  | start no earlier than 2007-09-18 |
| 41 | Approved first quality karak marble grey color | 15d | 2007-04-16 | 2007-05-04 |  |  |  |  | 231d |  | start no earlier than 2007-04-16 |
| 42 | Ajlon cornice stone to walls | 10d | 2007-05-01 | 2007-05-14 |  |  |  |  | 225d |  | start no earlier than 2007-05-01 |
| 43 | Precast terrazzo tiles, to floors, size 400*100*30 mm for guards rooms | 2d | 2007-04-16 | 2007-04-17 |  |  |  |  | 244d |  | start no earlier than 2007-04-16 |
| 44 | Approved first quality JERUSALEM stone, to floors of saloons, living, Tv and master bedrooms areas 600*600*20 mm thick | 6d | 2007-04-16 | 2007-04-23 |  |  |  |  | 224d | 0d | start no earlier than 2007-04-16 |
| 45 | To skirting size 600*100*6 mm thick | 3d | 2007-04-24 | 2007-04-26 | 44 |  |  |  | 224d | 0d |  |
| 46 | (STAND BY ITEM) DITTO BUT ITALIAN MARBLE, to floors of saloons, living, TV and master bedrooms areas 600*600*20 mm thick | 6d | 2007-04-16 | 2007-04-23 |  |  |  |  | 237d | 0d | start no earlier than 2007-04-16 |
| 47 | To skirting size 600*100*6 mm thick | 3d | 2007-04-24 | 2007-04-26 | 46 |  |  |  | 237d |  |  |
| 48 | Ditto but Omani or stone like ceramic tiles, to floors 400*400*20 mm thick | 5d | 2007-04-16 | 2007-04-20 |  |  |  |  | 208d | 0d | start no earlier than 2007-04-16 |
| 49 | To skirting size 300*100*6 mm thick | 4d | 2007-04-23 | 2007-04-26 | 48 |  |  |  | 208d | 0d |  |
| 50 | Imported Spanish Ceramic, To kitchens floors size 400*400*9 mm thick | 5d | 2007-04-27 | 2007-05-03 | 49 |  |  |  | 208d | 0d |  |
| 51 | Ditto but EMIRATES R.A.K ceramic, To floors, size 300*300*9 mm thick for maids rooms | 3d | 2007-05-04 | 2007-05-08 | 50 |  |  |  | 208d | 0d |  |
| 52 | To skirting, size 300*100*6 mm thick for maids rooms | 2d | 2007-05-09 | 2007-05-10 | 51 |  |  |  | 208d | 0d |  |
| 53 | Ditto but local ceramic for boiler and maids bathrooms 200*200*9 mm | 4d | 2007-05-11 | 2007-05-16 | 52 |  |  |  | 208d | 0d |  |
| 54 | One piece JERUSALEM stone to steps, to treads and risers | 5d | 2007-04-27 | 2007-05-03 | 45 |  |  |  | 224d | 0d |  |
| 55 | Skirting to flights 6 mm thick | 3d | 2007-05-04 | 2007-05-08 | 54 |  |  |  | 224d | 0d |  |
| 56 | One piece gravelled tiles to external steps, to treads and risers | 3d | 2007-05-09 | 2007-05-11 | 55 |  |  |  | 224d | 0d |  |
| 57 | Skirting to flights 6 mm thick | 2d | 2007-05-14 | 2007-05-15 | 56 |  |  |  | 224d |  |  |
| 58 | Precast interlock concrete cement floor tiles, to walkway at parking and ramps size 400*400*40 mm | 10d | 2007-12-03 | 2007-12-14 |  |  |  |  | 71d |  | start no earlier than 2007-12-03 |
| 59 | Standby itme ditto but basalt stone | 10d | 2007-12-03 | 2007-12-14 |  |  |  |  | 64d | 0d | start no earlier than 2007-12-03 |
| 60 | Precast concrete cement floor tiles, for external paving | 8d | 2007-12-17 | 2007-12-26 | 59 |  |  |  | 64d |  |  |
| 61 | Three coats cement and sand (1:4) plastereing, smooth finish, To walls, Internally | 90d | 2007-04-02 | 2007-08-03 |  |  |  |  | 166d |  | start no earlier than 2007-04-02 |
| 62 | To walls, Internally behind ceramic walls | 30d | 2007-05-02 | 2007-06-12 |  |  |  |  | 204d |  | start no earlier than 2007-05-02 |
| 63 | To walls, internlly for water tanks walls | 10d | 2007-04-02 | 2007-04-13 |  |  |  |  | 246d |  | start no earlier than 2007-04-02 |
| 64 | To walls, Externally | 12d | 2007-05-02 | 2007-05-17 |  |  |  |  | 197d | 0d | start no earlier than 2007-05-02 |
| 65 | Glazed imported SPANISH ceramic coloured wall tiles, to walls size 300*300*9 mm thick for bath rooms | 10d | 2007-05-17 | 2007-05-30 | 53 |  |  |  | 208d | 0d |  |
| 66 | Ditto but to walls size 100*100*9 mm thick mosaic for kitchens | 10d | 2007-05-23 | 2007-06-05 |  |  |  |  | 209d |  | start no earlier than 2007-05-23 |
| 67 | Ditto but JERUSALEM wall tiles for basement 1 entrance complete | 3d | 2007-05-23 | 2007-05-25 |  |  |  |  | 216d |  | start no earlier than 2007-05-23 |
| 68 | Ditto but local glazed colored ceramic wall tiles, To walls size 200*200*8 mm thick for Boiler | 5d | 2007-05-31 | 2007-06-06 | 65 |  |  |  | 208d |  |  |
| 69 | To walls size 200*200*8 mm thick for maids rooms (white colour) | 4d | 2007-06-04 | 2007-06-07 |  |  |  |  | 208d |  | start no earlier than 2007-06-04 |
| 70 | Ceiling finishes,Three coats cement and sand (1:4) plastering, smooth finish | 30d | 2007-07-09 | 2007-08-17 |  |  |  |  | 156d |  | start no earlier than 2007-07-09 |

| ID | Task | Duration | Start | Finish | Predecessors | Total slack | Free slack | Constraint |
| --- | --- | --- | --- | --- | --- | --- | --- | --- |
| 71 | JERUSALEM stone cladding, fixed to faces of concrete with 30 mm thick with cement mortar for parking columns | 5d | 2008-01-02 | 2008-01-08 |  | 46d | 0d | start no earlier than 2008-01-02 |
| 72 | JERUSALEM stone cladding, for main entrances | 3d | 2008-01-09 | 2008-01-11 | 71 | 46d | 0d |  |
| 73 | AJLOON stone cladding, for parking walls and entrance | 5d | 2008-01-14 | 2008-01-18 | 72 | 46d |  |  |
| 74 | Suspended ceilings, 12 mm thick gypsum board suspended ceiling panels finished with skim coat, including conceled galvanized suspension system, stepped decorations, strips, for different sevices | 5d | 2008-02-01 | 2008-02-07 |  | 32d |  | start no earlier than 2008-02-01 |
| 75 | 800mm*300 mm height gypsum cornice suspended finished with skim coat, for saloons, TV and dinning ceilings | 20d | 2008-02-01 | 2008-02-28 |  | 17d |  | start no earlier than 2008-02-01 |
| 76 | Internally Emulsion PVA-based paint matt finish for interior, To walls | 60d | 2007-08-01 | 2007-10-23 |  | 89d | 0d | start no earlier than 2007-08-01 |
| 77 | Externally, Resin base water proofing acrylic textured decorative coating, to exterior walls | 20d | 2007-05-21 | 2007-06-15 |  | 201d |  | start no earlier than 2007-05-21 |
| 78 | To walls at roof | 18d | 2007-08-01 | 2007-08-24 |  | 151d |  | start no earlier than 2007-08-01 |
| 79 | Non- toxic epoxy paint including primer all as specified, complete to floor, walls and ceiling of water tanks | 25d | 2007-05-18 | 2007-06-21 | 64 | 197d |  |  |
| 80 | CORNER GUARDS, supply and fix rubber corner guards for columns at parking areas, 100*100 mm, 1200 mm height | 6d | 2007-08-01 | 2007-08-08 |  | 163d |  | start no earlier than 2007-08-01 |
| 81 | Mirrors, 6 mm thick mirrors with 20 mm stainless steel frame including 8 mm thick plywood backing, size 1050*2600 mm high | 4d | 2007-11-30 | 2007-12-05 |  | 55d | 0d | start no earlier than 2007-11-30 |
| 82 | size 1600*1300 mm high | 3d | 2007-12-06 | 2007-12-10 | 81 | 55d | 0d |  |
| 83 | Size 800*1300 mm high | 7d | 2007-12-11 | 2007-12-19 | 82 | 55d | 0d |  |
| 84 | Local KARAK Marble countertop 30 mm thick with molding wash basin including 200 mm dropped cornice, size 1700*600 mm wide | 2d | 2007-12-20 | 2007-12-21 | 83 | 55d | 0d |  |
| 85 | Size 2800*600 mm wide | 1d | 2007-12-24 | 2007-12-24 | 84 | 55d | 0d |  |
| 86 | Size 2000*600 mm wide | 1d | 2007-12-25 | 2007-12-25 | 85 | 55d | 0d |  |
| 87 | Size 1800*600 mm wide | 1d | 2007-12-26 | 2007-12-26 | 86 | 55d | 0d |  |
| 88 | Size 1200*600 mm wide | 2d | 2007-12-27 | 2007-12-28 | 87 | 55d | 0d |  |
| 89 | Size 2200*600 mm wide | 2d | 2007-12-31 | 2008-01-01 | 88 | 55d | 0d |  |
| 90 | Size 1900*600 mm wide | 3d | 2008-01-02 | 2008-01-04 | 89 | 55d | 0d |  |
| 91 | Size 2600*600 mm wide | 1d | 2008-01-07 | 2008-01-07 | 90 | 55d |  |  |
| 92 | Planting, Agricultural soil of clean selected top soil suitable for planting purposes | 23d | 2008-02-18 | 2008-03-19 |  | 0d |  | start no earlier than 2008-02-18 |
| 93 | Slab on grade, 100 mm thick, to building | 4d | 2007-03-02 | 2007-03-07 | 5 | 274d |  |  |
