Schedule from MS Project, 2006-12-22 to 2008-03-18.
alanzy company

## Calendars

- Standard: Mon-Fri 08:00-12:00, 13:00-17:00; Sat-Sun off.

## Schedule

| ID | Task | Duration | Start | Finish | Predecessors | Baseline start | Baseline finish | Baseline duration | Total slack | Free slack | Constraint |
| --- | --- | --- | --- | --- | --- | --- | --- | --- | --- | --- | --- |
| 1 | Excavation to foundations level [Contractor #9 Eng. Ahmed Alumari] | 21d | 2006-12-22 | 2007-01-19 |  | 2006-12-22 | 2007-01-02 | 8d | 272d | 0d |  |
| 2 | Excavation for external works | 10d | 2006-12-22 | 2007-01-04 |  | 2006-12-22 | 2007-01-04 | 10d | 303d | 0d |  |
| 3 | Approved filling inside | 10d | 2007-03-16 | 2007-03-29 | 11 | 2007-03-16 | 2007-03-29 | 10d | 242d | 0d |  |
| 4 | Approved filling outside | 12d | 2007-03-01 | 2007-03-16 | 13 | 2007-03-01 | 2007-03-16 | 12d | 262d |  |  |
| 5 | Crushed aggregate base 200 mm thick inside building | 5d | 2007-03-30 | 2007-04-05 | 3 | 2007-03-30 | 2007-04-05 | 5d | 242d | 0d |  |
| 6 | Blinding 100 mm thick under foundations and tie beams | 5d | 2007-01-22 | 2007-01-26 | 1 | 2007-01-22 | 2007-01-26 | 5d | 272d | 0d |  |
| 7 | Blinding 50 mm thick under slabs on grade | 3d | 2007-02-26 | 2007-02-28 |  | 2007-02-26 | 2007-02-28 | 3d | 269d | 0d | start no earlier than 2007-02-26 |
| 8 | Blinding 100 mm thick under external works | 3d | 2007-01-05 | 2007-01-09 | 2 | 2007-01-05 | 2007-01-09 | 3d | 303d | 10d |  |
| 9 | Reinforced concrete for foundations | 15d | 2007-01-15 | 2007-02-02 |  | 2007-01-15 | 2007-02-02 | 15d | 292d |  | start no earlier than 2007-01-15 |
| 10 | Reinforced concrete for tie beams | 7d | 2007-04-13 | 2007-04-23 | 35 | 2007-04-13 | 2007-04-23 | 7d | 236d |  |  |
| 11 | Reinforced concrete for columns & column necks | 25d | 2007-02-09 | 2007-03-15 |  | 2007-02-09 | 2007-03-15 | 25d | 242d | 0d | start no earlier than 2007-02-09 |
| 12 | Reinforced concrete for slab on grade, 100 mm thick to external pavements | 5d | 2007-03-01 | 2007-03-07 | 7 | 2007-03-01 | 2007-03-07 | 5d | 269d |  |  |
| 13 | Reinforced concrete for external basement walls | 23d | 2007-01-29 | 2007-02-28 |  | 2007-01-29 | 2007-02-28 | 23d | 262d | 0d | start no earlier than 2007-01-29 |
| 14 | Reinforced concrete for water tank walls | 7d | 2007-01-24 | 2007-02-01 | 8 | 2007-01-24 | 2007-02-01 | 7d | 293d |  | start no earlier than 2007-01-24 |
| 15 | Reinforced concrete for external foundations | 8d | 2007-01-15 | 2007-01-24 |  | 2007-01-15 | 2007-01-24 | 8d | 285d | 0d | start no earlier than 2007-01-15 |
| 16 | Reinforced concrete for external walls | 14d | 2007-01-25 | 2007-02-13 | 15 | 2007-01-25 | 2007-02-13 | 14d | 285d |  |  |
| 17 | Reinforced concrete behind stone elevations | 45d | 2007-03-01 | 2007-05-02 |  | 2007-03-01 | 2007-05-02 | 45d | 229d |  | start no earlier than 2007-03-01 |
| 18 | Reinforced concrete for ribbed slabs, 310 mm thick | 70d | 2007-03-07 | 2007-06-12 |  | 2007-03-07 | 2007-06-12 | 70d | 200d |  | start no earlier than 2007-03-07 |
| 19 | Reinforced concrete for stair cases (steps & flights) inside | 15d | 2007-03-07 | 2007-03-27 |  | 2007-03-07 | 2007-03-27 | 15d | 255d |  | start no earlier than 2007-03-07 |
| 20 | Reinforced concrete for stair cases (steps & flights) outside | 10d | 2007-11-14 | 2007-11-27 | 76 | 2007-11-14 | 2007-11-27 | 10d | 80d |  | start no earlier than 2007-04-09 |
| 21 | Deformed high yield steel bar reinforcement for various diameters, generally | 25d | 2007-01-29 | 2007-03-02 | 6 | 2007-01-29 | 2007-03-02 | 25d | 272d |  |  |
| 22 | Smooth mild steel bar reinforcement for Y8 mm | 7d | 2007-01-09 | 2007-01-17 |  | 2007-01-09 | 2007-01-17 | 7d | 304d |  | start no earlier than 2007-01-09 |
| 23 | Hollow concrete blocks for walls, 100 mm thick | 7d | 2007-03-15 | 2007-03-23 |  | 2007-03-15 | 2007-03-23 | 7d | 257d |  | start no earlier than 2007-03-15 |
| 24 | Hollow concrete blocks for walls, 150 mm thick | 5d | 2007-03-15 | 2007-03-21 |  | 2007-03-15 | 2007-03-21 | 5d | 259d |  | start no earlier than 2007-03-15 |
| 25 | Hollow concrete blocks for walls, 200 mm thick | 3d | 2007-03-15 | 2007-03-19 |  | 2007-03-15 | 2007-03-19 | 3d | 261d |  | start no earlier than 2007-03-15 |
| 26 | Hollow concrete rib blocks | 10d | 2007-03-01 | 2007-03-14 |  | 2007-03-01 | 2007-03-14 | 10d | 264d |  | start no earlier than 2007-03-01 |
| 27 | concrete blocks, 100 mm thick for external walls of basement | 5d | 2007-03-15 | 2007-03-21 |  | 2007-03-15 | 2007-03-21 | 5d | 259d |  | start no earlier than 2007-03-15 |
| 28 | concrete blocks, 100 mm thick, behind the stone walls | 10d | 2007-02-22 | 2007-03-07 |  | 2007-02-22 | 2007-03-07 | 10d | 269d |  | start no earlier than 2007-02-22 |
| 29 | Foam concrete, to roofs | 3d | 2007-09-25 | 2007-09-27 |  | 2007-09-25 | 2007-09-27 | 3d | 120d | 0d | start no earlier than 2007-09-25 |
| 30 | Cement sand screed, to roofs | 3d | 2007-09-28 | 2007-10-02 | 29 | 2007-09-28 | 2007-10-02 | 3d | 120d |  |  |
| 31 | 4 mm thick torch applied modified bituminous water-proofing membrane | 5d | 2007-10-22 | 2007-10-26 |  | 2007-10-22 | 2007-10-26 | 5d | 102d |  | start no earlier than 2007-10-22 |
| 32 | 4 mm thick torch applied modified bituminous polymer water-proofing membrane, for slabs on grade | 5d | 2007-04-09 | 2007-04-13 |  | 2007-04-09 | 2007-04-13 | 5d | 242d |  | start no earlier than 2007-04-09 |
| 33 | 4 mm thick torch applied modified bituminous polymer water-proofing membrane, to basement walls | 6d | 2007-02-22 | 2007-03-01 |  | 2007-02-22 | 2007-03-01 | 6d | 273d |  | start no earlier than 2007-02-22 |
| 34 | Pvc water stop for water tank walls | 1d | 2008-03-18 | 2008-03-18 | 92 | 2008-03-18 | 2008-03-18 | 1d | 0d |  |  |
| 35 | Damp proofing membrane to basement walls | 10d | 2007-03-30 | 2007-04-12 |  | 2007-03-30 | 2007-04-12 | 10d | 236d | 0d | start no earlier than 2007-03-30 |
| 36 | Local ajlon stone, case 1 mechanical push | 46d | 2007-02-15 | 2007-04-19 |  | 2007-02-15 | 2007-04-19 | 46d | 238d |  | start no earlier than 2007-02-15 |
| 37 | Local ajlon stone, case 2 light chisled face finish | 46d | 2007-02-15 | 2007-04-19 |  | 2007-02-15 | 2007-04-19 | 46d | 238d |  | start no earlier than 2007-02-15 |
| 38 | Local ajlon stone, case 3 rough chirled face finish | 46d | 2007-02-15 | 2007-04-19 |  | 2007-02-15 | 2007-04-19 | 46d | 238d |  | start no earlier than 2007-02-15 |
| 39 | Local ajlon stone, case 4 face finish | 46d | 2007-02-15 | 2007-04-19 |  | 2007-02-15 | 2007-04-19 | 46d | 238d |  | start no earlier than 2007-02-15 |
| 40 | Stone coping local ajlon | 17d | 2007-09-18 | 2007-10-10 |  | 2007-09-18 | 2007-10-10 | 17d | 114d |  | start no earlier than 2007-09-18 |
| 41 | Approved first quality karak marble grey color | 12d | 2007-04-16 | 2007-05-01 |  | 2007-04-16 | 2007-05-01 | 12d | 230d |  | start no earlier than 2007-04-16 |
| 42 | Ajlon cornice stone to walls | 8d | 2007-05-01 | 2007-05-10 |  | 2007-05-01 | 2007-05-10 | 8d | 223d |  | start no earlier than 2007-05-01 |
| 43 | Precast terrazzo tiles, to floors, size 400*100*30 mm for guards rooms | 2d | 2007-04-16 | 2007-04-17 |  | 2007-04-16 | 2007-04-17 | 2d | 240d |  | start no earlier than 2007-04-16 |
| 44 | Approved first quality JERUSALEM stone, to floors of saloons, living, Tv and master bedrooms areas 600*600*20 mm thick | 30d | 2007-04-16 | 2007-05-25 |  | 2007-04-16 | 2007-05-25 | 30d | 184d | 0d | start no earlier than 2007-04-16 |
| 45 | To skirting size 600*100*6 mm thick | 10d | 2007-05-28 | 2007-06-08 | 44 | 2007-05-28 | 2007-06-08 | 10d | 184d | 0d |  |
| 46 | (STAND BY ITEM) DITTO BUT ITALIAN MARBLE, to floors of saloons, living, TV and master bedrooms areas 600*600*20 mm thick | 30d | 2007-04-16 | 2007-05-25 |  | 2007-04-16 | 2007-05-25 | 30d | 202d | 0d | start no earlier than 2007-04-16 |
| 47 | To skirting size 600*100*6 mm thick | 10d | 2007-05-28 | 2007-06-08 | 46 | 2007-05-28 | 2007-06-08 | 10d | 202d |  |  |
| 48 | Ditto but Omani or stone like ceramic tiles, to floors 400*400*20 mm thick | 30d | 2007-04-16 | 2007-05-25 |  | 2007-04-16 | 2007-05-25 | 30d | 170d | 0d | start no earlier than 2007-04-16 |
| 49 | To skirting size 300*100*6 mm thick | 10d | 2007-05-28 | 2007-06-08 | 48 | 2007-05-28 | 2007-06-08 | 10d | 170d | 0d |  |
| 50 | Imported Spanish Ceramic, To kitchens floors size 400*400*9 mm thick | 5d | 2007-06-11 | 2007-06-15 | 49 | 2007-06-11 | 2007-06-15 | 5d | 170d | 0d |  |
| 51 | Ditto but EMIRATES R.A.K ceramic, To floors, size 300*300*9 mm thick for maids rooms | 2d | 2007-06-18 | 2007-06-19 | 50 | 2007-06-18 | 2007-06-19 | 2d | 170d | 0d |  |
| 52 | To skirting, size 300*100*6 mm thick for maids rooms | 2d | 2007-06-20 | 2007-06-21 | 51 | 2007-06-20 | 2007-06-21 | 2d | 170d | 0d |  |
| 53 | Ditto but local ceramic for boiler and maids bathrooms 200*200*9 mm | 4d | 2007-06-22 | 2007-06-27 | 52 | 2007-06-22 | 2007-06-27 | 4d | 170d | 0d |  |
| 54 | One piece JERUSALEM stone to steps, to treads and risers | 10d | 2007-06-11 | 2007-06-22 | 45 | 2007-06-11 | 2007-06-22 | 10d | 184d | 0d |  |
| 55 | Skirting to flights 6 mm thick | 5d | 2007-06-25 | 2007-06-29 | 54 | 2007-06-25 | 2007-06-29 | 5d | 184d | 0d |  |
| 56 | One piece gravelled tiles to external steps, to treads and risers | 2d | 2007-07-02 | 2007-07-03 | 55 | 2007-07-02 | 2007-07-03 | 2d | 184d | 0d |  |
| 57 | Skirting to flights 6 mm thick | 1d | 2007-07-04 | 2007-07-04 | 56 | 2007-07-04 | 2007-07-04 | 1d | 184d |  |  |
| 58 | Precast interlock concrete cement floor tiles, to walkway at parking and ramps size 400*400*40 mm | 10d | 2007-12-03 | 2007-12-14 |  | 2007-12-03 | 2007-12-14 | 10d | 67d |  | start no earlier than 2007-12-03 |
| 59 | Standby itme ditto but basalt stone | 10d | 2007-12-03 | 2007-12-14 |  | 2007-12-03 | 2007-12-14 | 10d | 62d | 0d | start no earlier than 2007-12-03 |
| 60 | Precast concrete cement floor tiles, for external paving | 5d | 2007-12-17 | 2007-12-21 | 59 | 2007-12-17 | 2007-12-21 | 5d | 62d |  |  |
| 61 | Three coats cement and sand (1:4) plastereing, smooth finish, To walls, Internally | 80d | 2007-04-02 | 2007-07-20 |  | 2007-04-02 | 2007-07-20 | 80d | 172d |  | start no earlier than 2007-04-02 |
| 62 | To walls, Internally behind ceramic walls | 10d | 2007-05-02 | 2007-05-15 |  | 2007-05-02 | 2007-05-15 | 10d | 220d |  | start no earlier than 2007-05-02 |
| 63 | To walls, internlly for water tanks walls | 6d | 2007-04-02 | 2007-04-09 |  | 2007-04-02 | 2007-04-09 | 6d | 246d |  | start no earlier than 2007-04-02 |
| 64 | To walls, Externally | 5d | 2007-05-02 | 2007-05-08 |  | 2007-05-02 | 2007-05-08 | 5d | 204d | 0d | start no earlier than 2007-05-02 |
| 65 | Glazed imported SPANISH ceramic coloured wall tiles, to walls size 300*300*9 mm thick for bath rooms | 15d | 2007-06-28 | 2007-07-18 | 53 | 2007-06-28 | 2007-07-18 | 15d | 170d | 0d |  |
| 66 | Ditto but to walls size 100*100*9 mm thick mosaic for kitchens | 10d | 2007-05-23 | 2007-06-05 |  | 2007-05-23 | 2007-06-05 | 10d | 205d |  | start no earlier than 2007-05-23 |
| 67 | Ditto but JERUSALEM wall tiles for basement 1 entrance complete | 5d | 2007-05-23 | 2007-05-29 |  | 2007-05-23 | 2007-05-29 | 5d | 210d |  | start no earlier than 2007-05-23 |
| 68 | Ditto but local glazed colored ceramic wall tiles, To walls size 200*200*8 mm thick for Boiler | 4d | 2007-07-19 | 2007-07-24 | 65 | 2007-07-19 | 2007-07-24 | 4d | 170d |  |  |
| 69 | To walls size 200*200*8 mm thick for maids rooms (white colour) | 3d | 2007-06-04 | 2007-06-06 |  | 2007-06-04 | 2007-06-06 | 3d | 204d |  | start no earlier than 2007-06-04 |
| 70 | Ceiling finishes,Three coats cement and sand (1:4) plastering, smooth finish | 30d | 2007-07-09 | 2007-08-17 |  | 2007-07-09 | 2007-08-17 | 30d | 152d |  | start no earlier than 2007-07-09 |

| ID | Task | Duration | Start | Finish | Predecessors | Baseline start | Baseline finish | Baseline duration | Total slack | Free slack | Constraint |
| --- | --- | --- | --- | --- | --- | --- | --- | --- | --- | --- | --- |
| 71 | JERUSALEM stone cladding, fixed to faces of concrete with 30 mm thick with cement mortar for parking columns | 3d | 2008-01-02 | 2008-01-04 |  | 2008-01-02 | 2008-01-04 | 3d | 45d | 0d | start no earlier than 2008-01-02 |
| 72 | JERUSALEM stone cladding, for main entrances | 3d | 2008-01-07 | 2008-01-09 | 71 | 2008-01-07 | 2008-01-09 | 3d | 45d | 0d |  |
| 73 | AJLOON stone cladding, for parking walls and entrance | 4d | 2008-01-10 | 2008-01-15 | 72 | 2008-01-10 | 2008-01-15 | 4d | 45d |  |  |
| 74 | Suspended ceilings, 12 mm thick gypsum board suspended ceiling panels finished with skim coat, including conceled galvanized suspension system, stepped decorations, strips, for different sevices | 4d | 2008-02-01 | 2008-02-06 |  | 2008-02-01 | 2008-02-06 | 4d | 29d |  | start no earlier than 2008-02-01 |
| 75 | 800mm*300 mm height gypsum cornice suspended finished with skim coat, for saloons, TV and dinning ceilings | 7d | 2008-02-01 | 2008-02-11 |  | 2008-02-01 | 2008-02-11 | 7d | 26d |  | start no earlier than 2008-02-01 |
| 76 | Internally Emulsion PVA-based paint matt finish for interior, To walls | 75d | 2007-08-01 | 2007-11-13 |  | 2007-08-01 | 2007-11-13 | 75d | 80d | 0d | start no earlier than 2007-08-01 |
| 77 | Externally, Resin base water proofing acrylic textured decorative coating, to exterior walls | 22d | 2007-05-21 | 2007-06-19 |  | 2007-05-21 | 2007-06-19 | 22d | 195d |  | start no earlier than 2007-05-21 |
| 78 | To walls at roof | 18d | 2007-08-01 | 2007-08-24 |  | 2007-08-01 | 2007-08-24 | 18d | 147d |  | start no earlier than 2007-08-01 |
| 79 | Non- toxic epoxy paint including primer all as specified, complete to floor, walls and ceiling of water tanks | 21d | 2007-05-09 | 2007-06-06 | 64 | 2007-05-09 | 2007-06-06 | 21d | 204d |  |  |
| 80 | CORNER GUARDS, supply and fix rubber corner guards for columns at parking areas, 100*100 mm, 1200 mm height | 9d | 2007-08-01 | 2007-08-13 |  | 2007-08-01 | 2007-08-13 | 9d | 156d |  | start no earlier than 2007-08-01 |
| 81 | Mirrors, 6 mm thick mirrors with 20 mm stainless steel frame including 8 mm thick plywood backing, size 1050*2600 mm high | 3d | 2007-11-30 | 2007-12-04 |  | 2007-11-30 | 2007-12-04 | 3d | 47d | 0d | start no earlier than 2007-11-30 |
| 82 | size 1600*1300 mm high | 6d | 2007-12-05 | 2007-12-12 | 81 | 2007-12-05 | 2007-12-12 | 6d | 47d | 0d |  |
| 83 | Size 800*1300 mm high | 9d | 2007-12-13 | 2007-12-25 | 82 | 2007-12-13 | 2007-12-25 | 9d | 47d | 0d |  |
| 84 | Local KARAK Marble countertop 30 mm thick with molding wash basin including 200 mm dropped cornice, size 1700*600 mm wide | 2d | 2007-12-26 | 2007-12-27 | 83 | 2007-12-26 | 2007-12-27 | 2d | 47d | 0d |  |
| 85 | Size 2800*600 mm wide | 1d | 2007-12-28 | 2007-12-28 | 84 | 2007-12-28 | 2007-12-28 | 1d | 47d | 0d |  |
| 86 | Size 2000*600 mm wide | 1d | 2007-12-31 | 2007-12-31 | 85 | 2007-12-31 | 2007-12-31 | 1d | 47d | 0d |  |
| 87 | Size 1800*600 mm wide | 1d | 2008-01-01 | 2008-01-01 | 86 | 2008-01-01 | 2008-01-01 | 1d | 47d | 0d |  |
| 88 | Size 1200*600 mm wide | 2d | 2008-01-02 | 2008-01-03 | 87 | 2008-01-02 | 2008-01-03 | 2d | 47d | 0d |  |
| 89 | Size 2200*600 mm wide | 2d | 2008-01-04 | 2008-01-07 | 88 | 2008-01-04 | 2008-01-07 | 2d | 47d | 0d |  |
| 90 | Size 1900*600 mm wide | 3d | 2008-01-08 | 2008-01-10 | 89 | 2008-01-08 | 2008-01-10 | 3d | 47d | 0d |  |
| 91 | Size 2600*600 mm wide | 1d | 2008-01-11 | 2008-01-11 | 90 | 2008-01-11 | 2008-01-11 | 1d | 47d |  |  |
| 92 | Planting, Agricultural soil of clean selected top soil suitable for planting purposes | 21d | 2008-02-18 | 2008-03-17 |  | 2008-02-18 | 2008-03-17 | 21d | 0d |  | start no earlier than 2008-02-18 |
| 93 | Slab on grade, 100 mm thick, to building | 6d | 2007-04-06 | 2007-04-13 | 5 | 2007-04-06 | 2007-04-13 | 6d | 242d |  |  |
